# ROC Planning - Phase D-E1

Schedule from MS Project XML, 2014-01-01 to 2020-06-26, 7 hours a day, A marks actual dates.
Suivi des développements du projet ROC
LESIA, Observatoire de Paris

## Calendars

- Standard: Mon-Fri 08:00-12:00, 13:00-17:00; Sat-Sun off. Exceptions (off unless hours are given): 2017-10-03 08:00-12:00, 13:00-17:00, 2019-02-15 08:00-12:00, 13:00-17:00, 2019-06-15 08:00-12:00, 13:00-17:00, 2020-02-15 08:00-12:00, 13:00-17:00.

## Resources

| Resource |
| --- |
| X.Bonnin |
| Q.N.Nguyen |
| T.Sauzière |
| M.Duarte |
| S.Lion |
| A.Aboubacar |
| O.Alexandrova |
| M.Maksimvovic |
| A.Vecchio |
| L.Matteini |
| Y.de Conchy |
| N.Fuller |
| G.Duvauchelle |
| CDD IE2 (TBD) |
| THR support |
| TDS support |
| LFR support |
| BIAS support |
| SCM support |
| CNES support |
| TBD |
| RPW flight S/W support |
| S.Papais (NEXEYA) |
| D.Berard |
| DPU software support |
| MOC support |
| SOC support |
| B.Cecconi |
| Solo PIs support |
| SPICE support |
| SWA support |
| EPD support |
| MAG support |
| LESIA AIT/AIV support |
| MEB support |
| System support |
| E.Holle |

## Schedule

| ID | WBS | Task | Type | Duration | Start | Finish | Predecessors | Complete | Remaining | Baseline start | Baseline finish | Baseline duration | Total slack | Free slack | Constraint | Work |
| --- | --- | --- | --- | --- | --- | --- | --- | --- | --- | --- | --- | --- | --- | --- | --- | --- |
| 1 | 1 | **RPW MILESTONES** |  | 1429.86d? | 2015-09-01 A | 2020-06-15 |  | 99% | 9.89d? | 2015-09-01 | 2017-12-05 | 674.71d | 9.57d |  |  |  |
| 2 | 1.1 | **PHASE D** |  | 707.86d | 2015-09-01 A | 2018-01-16 A |  | 100% |  |  |  |  |  |  |  |  |
| 3 | 1.1.1 | **AIT/AIV activities** |  | 525.71d | 2015-09-01 A | 2017-06-06 A |  | 100% |  | 2015-09-01 | 2017-06-06 | 525.71d |  |  |  |  |
| 4 | 1.1.1.1 | DPU SBM1/SBM2 detection algo. validation campaign |  | 248.43d | 2015-09-01 A | 2016-06-30 A | 105 | 100% |  | 2015-09-01 | 2016-06-30 | 248.43d |  |  | start no earlier than 2015-01-01 |  |
| 5 | 1.1.1.2 | RPW EM2 blank tests campaign |  | 123.43d | 2016-04-14 A | 2016-09-13 A |  | 100% |  | 2016-04-14 | 2016-09-13 | 123.43d |  |  | must start on 2016-04-14 |  |
| 6 | 1.1.1.3 | RPW PFM thermal calibration campaign |  | 46.86d | 2016-11-14 A | 2017-01-10 A | 5, 120 | 100% |  | 2016-11-14 | 2017-01-10 | 46.86d? |  |  | must start on 2016-11-14 |  |
| 7 | 1.1.1.4 | RPW PFM delta calibration campaign |  | 12d | 2017-05-23 A | 2017-06-06 A | 6, 366SS | 100% |  | 2017-05-23 | 2017-06-06 | 12d |  |  | must start on 2017-05-23 |  |
| 8 | 1.1.2 | **Instrument main delivery** |  | 179.43d | 2017-06-08 | 2018-01-16 |  |  |  | 2017-06-08 | 2017-12-05 | 147.29d | 731.57d |  |  |  |
| 9 | 1.1.2.1 | MEB PFM datapackage delivery | milestone | 0d | 2017-06-08 A | 2017-06-08 A | 7 | 100% |  | 2017-06-08 | 2017-06-08 | 1d |  |  | must finish on 2017-06-08 |  |
| 10 | 1.1.2.2 | ANT PFM datapackage delivery (TBC) | milestone | 0d | 2018-01-16 | 2018-01-16 |  |  |  | 2017-12-05 | 2017-12-05 | 1d | 731.57d |  | start no earlier than 2018-01-15 |  |
| 11 | 1.2 | **PHASE E1** |  | 91d? | 2020-02-25 | 2020-06-15 |  |  |  |  |  |  | 9.57d |  |  |  |
| 12 | 1.2.1 | **RPW-related operations timeline** |  | 91d? | 2020-02-25 | 2020-06-15 |  |  |  |  |  |  | 9.57d |  |  |  |
| 13 | 1.2.1.1 | **LEOP (schedule TBD)** |  | 2d? | 2020-02-25 | 2020-02-26 |  |  |  |  |  |  | 98.57d |  |  |  |
| 14 | 1.2.1.1.1 | iBoom deployment (TBC) | milestone | 1d? | 2020-02-25 | 2020-02-25 | 53 |  |  | 2019-02-18 | 2019-02-19 | 1d? | 98.57d | 0d |  |  |
| 15 | 1.2.1.1.2 | ANT deployements (TBC) | milestone | 1d? | 2020-02-26 | 2020-02-26 | 14 |  |  | 2019-02-19 | 2019-02-20 | 1d? | 98.57d |  |  |  |
| 16 | 1.2.1.2 | **NECP (schedule TBD)** |  | 1d? | 2020-06-12 | 2020-06-15 |  |  |  |  |  |  | 9.57d |  |  |  |
| 17 | 1.2.1.2.1 | Interference campaign | milestone | 0d? | 2020-06-12 | 2020-06-12 | 54 |  |  | 2019-02-26 | 2019-02-26 | 0d? | 9.57d | 0d | start no earlier than 2019-02-26 |  |
| 18 | 1.2.1.2.2 | RPW-PAS filtering tune | milestone | 0d? | 2020-06-12 | 2020-06-12 | 17 |  |  | 2019-02-26 | 2019-02-26 | 0d? | 10.57d |  |  |  |
| 19 | 1.2.1.2.3 | TDS/LFR software validation | milestone | 0d? | 2020-06-12 | 2020-06-12 | 17 |  |  | 2019-02-26 | 2019-02-26 | 0d? | 10.57d |  |  |  |
| 20 | 1.2.1.2.4 | SPICE HSD <-> +Z ANT bending effect characterization | milestone | 0d? | 2020-06-12 | 2020-06-12 | 17 |  |  | 2019-02-26 | 2019-02-26 | 0d? | 9.57d | 0d |  |  |
| 21 | 1.2.1.2.5 | SBM1/SBM2 detection algo. validation |  | 1d? | 2020-06-12 | 2020-06-15 | 20 |  |  |  |  |  | 9.57d |  |  |  |
| 22 | 2 | **SOLO MILESTONES** |  | 1270.57d? | 2016-03-15 | 2020-06-15 |  |  |  | 2016-03-15 | 2018-10-03 | 761.29d | 9.57d |  |  | 3184h |
| 23 | 2.1 | **PHASE D** |  | 918.57d? | 2016-03-15 | 2019-04-12 |  |  |  |  |  |  | 361.57d |  |  | 3184h |
| 24 | 2.1.1 | **S/C AIT/AIV activities** |  | 81.14d? | 2018-02-01 | 2018-05-10 |  |  |  | 2018-02-01 | 2018-02-06 | 4d | 636.71d |  |  |  |
| 25 | 2.1.1.1 | Instruments EMC campaign on-ground |  | 4d? | 2018-02-01 | 2018-02-06 |  |  |  | 2018-02-01 | 2018-02-06 | 4d? | 713.86d |  | must start on 2018-02-01 |  |
| 26 | 2.1.1.2 | S20 IIC campaign |  | 1d? | 2018-05-10 | 2018-05-10 |  |  |  |  |  |  | 636.71d |  | start no earlier than 2018-05-10 |  |

Notes:
- 25: ROC is not directly involved in this campaign. / However, the RPW CNES team is in charge of providing the RPW raw data, as MEB GSE test log XML format files, to the ROC

| ID | WBS | Task | Type | Duration | Start | Finish | Predecessors | Complete | Baseline start | Baseline finish | Baseline duration | Total slack | Free slack | Constraint | Work |
| --- | --- | --- | --- | --- | --- | --- | --- | --- | --- | --- | --- | --- | --- | --- | --- |
| 27 | 2.1.2 | **SOC IT I/F tests** |  | 336d? | 2016-08-22 | 2017-10-05 |  |  | 2016-08-22 | 2017-10-03 | 333.71d | 813.86d |  |  |  |
| 28 | 2.1.2.1 | SOC GFTS test validation | milestone | 0d | 2017-04-04 A | 2017-04-04 A |  | 100% | 2017-04-04 | 2017-04-04 | 0d |  |  | start no earlier than 2017-04-04 |  |
| 29 | 2.1.2.2 | TMC compatibility test validation | milestone | 0d | 2016-08-22 A | 2016-08-22 A |  | 100% | 2016-08-22 | 2016-08-22 | 0d |  |  | start no earlier than 2016-08-22 |  |
| 30 | 2.1.2.3 | E-FECS compatibility test validation | milestone | 0d | 2016-08-22 A | 2016-08-22 A |  | 100% | 2016-08-22 | 2016-08-22 | 0d |  |  | start no earlier than 2016-08-22 |  |
| 31 | 2.1.2.4 | IOR compatibility test validation | milestone | 0d | 2017-08-23 A | 2017-08-23 A |  | 100% | 2017-08-23 | 2017-08-23 | 0d |  |  | start no earlier than 2017-08-23 |  |
| 32 | 2.1.2.5 | TMC/E-FECS integration test |  | 1d? | 2017-10-05 | 2017-10-05 | 28, 29, 30 |  | 2017-10-03 | 2017-10-03 | 1d? | 813.86d |  | start no earlier than 2017-10-05 |  |
| 33 | 2.1.3 | **SOC LLVM delivery schedule** |  | 521.14d | 2016-03-15 | 2017-12-13 |  |  | 2016-03-15 | 2017-12-15 | 524.57d | 759d |  |  |  |
| 34 | 2.1.3.1 | "Hello World" version delivery | milestone | 0d | 2016-03-15 A | 2016-03-15 A | 114 | 100% | 2016-03-15 | 2016-03-15 | 0d |  |  | start no earlier than 2016-03-15 |  |
| 35 | 2.1.3.2 | RPW Low Latency Data Description (LLDDD) Document issue 1 delivery | milestone | 0d | 2016-03-15 A | 2016-03-15 A |  | 100% | 2016-03-15 | 2016-03-15 | 0d |  |  | start no earlier than 2016-03-15 |  |
| 36 | 2.1.3.3 | "Testcard" scenario LL01 CDF delivery | milestone | 0d | 2017-03-08 | 2017-03-08 |  |  | 2017-03-08 | 2017-03-08 | 0d | 987.57d |  | start no earlier than 2017-03-08 |  |
| 37 | 2.1.3.4 | "Processing" version delivery | milestone | 0d | 2017-10-13 | 2017-10-13 | 144 |  | 2017-11-14 | 2017-11-14 | 0d | 807d |  | must finish on 2017-10-13 |  |
| 38 | 2.1.3.5 | "Processing + test" version delivery | milestone | 0d | 2017-12-13 | 2017-12-13 | 145, 399 |  | 2017-12-15 | 2017-12-15 | 0d | 759d |  | start no earlier than 2017-12-12 |  |
| 39 | 2.1.4 | **MOC IT I/F tests** |  | 0d? | 2017-12-04 | 2017-12-04 |  |  | 2017-12-04 | 2018-10-03 | 248d | 766.86d |  |  |  |
| 40 | 2.1.4.1 | PDOR/MDOR compatibility test passed (date TBC) | milestone | 0d? | 2017-12-04 | 2017-12-04 |  |  | 2017-12-04 | 2018-10-03 | 248d | 766.86d |  | start no earlier than 2017-12-04 |  |
| 41 | 2.1.5 | **System Validation Tests (SVT)** |  | 194.29d? | 2018-08-15 | 2019-04-09 |  |  | 2017-10-17 | 2018-09-06 | 265.71d | 364.71d |  |  | 1384h |
| 42 | 2.1.5.1 | SVT0: devoted to unit-level commanding (RPW not involved) |  | 2.29d | 2018-08-15 | 2018-08-16 | 262FS+1min |  | 2017-10-17 | 2017-10-18 | 2.29d | 548.71d | 0d | start no earlier than 2018-08-15 |  |
| 43 | 2.1.5.2 | SVT1: to validate closed loop behaviour (date TBC) |  | 4d? | 2019-04-01 | 2019-04-04 | 42, 269FS+3min |  | 2018-02-01 | 2018-02-06 | 4d? | 364.71d | 0d | start no earlier than 2019-04-01 | 1384h |
| 44 | 2.1.5.3 | SVT2: at the launch site, to perform last minute validation (date TBC) |  | 4d? | 2019-04-04 | 2019-04-09 | 43 |  | 2018-09-03 | 2018-09-06 | 4d? | 364.71d |  | start no earlier than 2018-09-03 |  |
| 45 | 2.1.6 | **System Operations Validation (SOV)** |  | 453.29d? | 2017-10-05 | 2019-04-12 |  |  | 2017-10-03 | 2018-04-10 | 154.43d | 361.57d |  |  | 1800h |
| 46 | 2.1.6.1 | SOV0: Data Distribution interface Test (Date TBC) |  | 2d? | 2017-12-01 | 2017-12-04 |  |  | 2017-12-01 | 2017-12-04 | 2d? | 766d |  | start no earlier than 2017-12-01 | 1800h |
| 47 | 2.1.6.2 | SOV1: MOC/SOC interface Test (Data TBC) |  | 2d? | 2017-10-05 | 2017-10-06 |  |  | 2017-10-03 | 2017-10-04 | 2d? | 433.29d | 144d | start no earlier than 2017-10-05 |  |
| 48 | 2.1.6.3 | SOV2-0: CP E2E test 0th |  | 7d? | 2018-04-02 | 2018-04-10 | 47 |  |  |  |  | 289.29d |  | start no earlier than 2018-04-02 |  |
| 49 | 2.1.6.4 | SOV2: CP End-to-end Test (Date TBC) |  | 7d? | 2019-04-01 | 2019-04-09 | 47, 48, 150FS+4d, 278FS+4min |  | 2018-04-02 | 2018-04-04 | 3d? | 0d |  | must start on 2019-04-01 |  |
| 50 | 2.1.6.5 | SOV3: OBSM End-to-End Test (Date TBC) |  | 3d? | 2019-04-10 | 2019-04-12 | 49FS+1d |  | 2018-04-05 | 2018-04-10 | 3d? | 253d | 252.99d |  |  |

Notes:
- 28: ROC has to implement GFTS node from LESIA side / SOC has to test it
- 29: From ROC side, test only consists of checking TMC file sent by SOC and returning feedbacks
- 30: From ROC side, test only consists of checking E-FECS file sent by SOC and returning feedbacks
- 32: Exact date is TBD
- 40: Tests will consist of providing MDOR/PDOR format files to MOC / Exacte date and specification of test are unknown
- 46: Test the data distribution interfaces between the MOC and the ROC.
- 47: Will involve instrument inputs.
- 49: Will involve In Situ (IS) instruments, and some limited Remote Sensing (RS) participation
- 50: Will involve all instruments

| ID | WBS | Task | Type | Duration | Start | Finish | Predecessors | Complete | Remaining | Baseline start | Baseline finish | Baseline duration | Total slack | Free slack | Constraint | Work |
| --- | --- | --- | --- | --- | --- | --- | --- | --- | --- | --- | --- | --- | --- | --- | --- | --- |
| 51 | 2.2 | **PHASE E** |  | 99d? | 2020-02-15 | 2020-06-15 |  |  |  |  |  |  | -281.86d | 0d |  |  |
| 52 | 2.2.1 | **MISSION PHASES** |  | 99d? | 2020-02-15 | 2020-06-15 |  |  |  |  |  |  | -281.86d | 0d |  |  |
| 53 | 2.2.1.1 | LEOP |  | 8d | 2020-02-15 | 2020-02-25 | 50FS+6min, 82FS+4min |  |  |  |  |  | 0d |  | must start on 2020-02-15 |  |
| 54 | 2.2.1.2 | NECP |  | 90d | 2020-02-25 | 2020-06-12 | 53 |  |  | 2019-02-23 | 2019-02-26 | 1.29d | -289.86d | 0d |  |  |
| 55 | 2.2.1.3 | CP start |  | 1d? | 2020-06-12 | 2020-06-15 | 54 |  |  |  |  |  | 9.57d |  |  |  |
| 56 | 3 | **ROC MILESTONES** |  | 1241.29d? | 2016-05-01 A | 2020-06-26 |  | 2% | 1215.35d? | 2016-05-01 | 2019-06-28 | 943d | -1.14d | 0d |  | 14h |
| 57 | 3.1 | **ROC-CNES convention datapackage deliveries** |  | 1241.29d | 2016-05-01 | 2020-06-26 |  |  |  | 2016-05-01 | 2019-06-28 | 943d | -1.14d | 0d |  |  |
| 58 | 3.1.1 | Lot6 evt1 datapackage delivery | milestone | 0d | 2016-05-01 A | 2016-05-01 A | 115 | 100% |  | 2016-05-01 | 2016-05-01 | 0d |  |  | must start on 2016-04-29 |  |
| 59 | 3.1.2 | Lot6 evt2 datapackage delivery | milestone | 0d | 2016-12-15 A | 2016-12-15 A | 120 | 100% |  | 2016-12-15 | 2016-12-15 | 0d |  |  | must start on 2016-12-15 |  |
| 60 | 3.1.3 | Lot6 evt3 datapackage delivery | milestone | 0d | 2018-03-30 | 2018-03-30 | 150 |  |  | 2017-12-15 | 2017-12-15 | 0d | 671d |  | must start on 2018-03-30 |  |
| 61 | 3.1.4 | Lot6 evt4 datapackage delivery | milestone | 0d | 2019-06-14 | 2019-06-14 | 193 |  |  | 2018-09-28 | 2018-09-28 | 0d | 310.86d |  | must start on 2019-06-14 |  |
| 62 | 3.1.5 | Lot6 evt5 datapackage delivery | milestone | 0d | 2020-06-26 | 2020-06-26 | 210 |  |  | 2019-06-28 | 2019-06-28 | 0d | 0d |  | must start on 2020-06-26 |  |
| 63 | 3.2 | **ROC Key Points & Reviews** |  | 744.43d? | 2017-01-02 A | 2019-07-01 |  | 2% | 728.87d? | 2016-06-12 | 2018-10-01 | 685.71d | -165.71d | 0d |  | 14h |
| 64 | 3.2.1 | **ROC Preliminary Design Key Point (PDKP)** |  | 131.57d | 2017-01-02 A | 2017-06-12 |  | 3% | 128.09d | 2016-06-12 | 2017-06-09 | 297d | -165.71d | 0d |  |  |
| 65 | 3.2.1.1 | PDKP datapackage delivery | milestone | 0d | 2017-01-02 A | 2017-01-02 A | 87, 88, 89, 90, 91, 395 | 100% |  | 2017-01-02 | 2017-01-02 | 0d |  |  | must start on 2017-01-02 |  |
| 66 | 3.2.1.2 | PDKP meeting | milestone | 1d | 2017-01-16 A | 2017-01-16 A | 65 | 100% |  | 2017-01-16 | 2017-01-16 | 1d |  |  | must start on 2017-01-16 |  |
| 67 | 3.2.1.3 | PDKP Reviewers feedback |  | 110.29d | 2017-01-17 | 2017-06-01 | 66FS+1d |  |  | 2017-01-17 | 2017-01-23 | 4d | 917.57d |  |  |  |
| 68 | 3.2.1.4 | PDKP ROC response | milestone | 2d | 2017-06-01 A | 2017-06-02 A | 67 | 100% |  | 2017-06-09 | 2017-06-09 | 1d |  |  |  |  |
| 69 | 3.2.1.5 | PDKP conclusion meeting | milestone | 0d | 2017-06-12 A | 2017-06-12 A | 68FS+2d | 100% |  | 2016-06-12 | 2016-06-12 | 0d |  |  | must start on 2016-06-12 |  |
| 70 | 3.2.2 | **ROC End of Design Key Point (EDKP)** |  | 51.43d? | 2017-11-17 | 2018-01-22 |  |  |  | 2017-11-17 | 2017-12-14 | 20.57d | 0d |  |  |  |
| 71 | 3.2.2.1 | EDKP datapackage delivery | milestone | 0d | 2017-11-17 | 2017-11-17 | 256, 257, 400, 401 |  |  | 2017-11-17 | 2017-11-17 | 0d | 0d |  | must finish on 2017-11-17 |  |
| 72 | 3.2.2.2 | EDKP meeting | milestone | 1d | 2017-11-28 | 2017-11-28 | 71FS+11.43d |  |  | 2017-11-28 | 2017-11-28 | 1d | 0d |  | must start on 2017-11-28 |  |
| 73 | 3.2.2.3 | EDKP Reviewers feedback |  | 10.43d? | 2017-11-29 | 2017-12-12 | 72FS+1d |  |  | 2017-11-29 | 2017-12-07 | 7d? | 11d | 0d | start no earlier than 2017-05-31 |  |
| 74 | 3.2.2.4 | EDKP ROC response |  | 8.86d? | 2017-12-12 | 2017-12-22 | 73 |  |  | 2017-12-07 | 2017-12-11 | 2d? | 11d |  | finish no later than 2018-01-08 |  |
| 75 | 3.2.2.5 | EDKP question/answer meeting | milestone | 0d | 2018-01-09 | 2018-01-09 | 74FS+2d |  |  | 2017-12-14 | 2017-12-14 | 0d | 0d | 10.29d | must start on 2018-01-09 |  |
| 76 | 3.2.2.6 | EKDP final report release | milestone | 0d | 2018-01-22 | 2018-01-22 | 75 |  |  |  |  |  | 727d |  | start no earlier than 2018-01-22 |  |

Notes:
- 65: Datapackage content: / - CIRD / - PMP / - SPAP / - SDP / - RSSS / - RSDD / - RDP / - REG / - REGU / - MDBDD / - ROC dev. planning / Datapackage must include also AD/RD.
- 71: ROC End of Design Key Point (EDKP) Deliverables / ———— / Requirements / - ROC Concept & Implementation Requirements Document (CIRD) / - ROC Human-Machine Interfaces User Requirements (HMIUR) / Plans / - ROC Project Management Plan (PMP) / - ROC Software Development Plan (SDP) / - ROC Operations Management Plan (OMP) / - ROC Software Product Assurance Plan (SDAP) / - ROC Validation Plan (RVP) / Specification & Design / - ROC Software System Specification (RSSS) / - ROC Software System Design Document (RSSDD) / - ROC Mission Database Description Document (MDBDD) / - RPW Low Latency Virtual Machine Design Document (LLVMDD) / ICD / - RPW Calibration Software ICD (RCSICD) / - BIAS operations ICD (BOICD) / NTT / - RPW Data Products (RDP) / - Dataset Description Document for RPW Low Latency CDF Files (DDDRLLCF) / - ROC Engineering Guidelines (REG) / - ROC Engineering Guidelines for External Users (REGU) / - Software Configuration File / - Software Reuse File / Planning / - ROC development planning / Matrix / - Traceability Matrix
- 75: Might be a telecon

| ID | WBS | Task | Type | Duration | Start | Finish | Predecessors | Complete | Remaining | Baseline start | Baseline finish | Baseline duration | Total slack | Free slack | Constraint | Resources | Work | Actual work |
| --- | --- | --- | --- | --- | --- | --- | --- | --- | --- | --- | --- | --- | --- | --- | --- | --- | --- | --- |
| 77 | 3.2.3 | **ROC Acceptance Review (AR) - Details and organization are TBD** |  | 191.29d? | 2018-11-09 | 2019-07-01 |  |  |  | 2017-11-28 | 2018-10-01 | 250.29d | 163.29d |  |  |  | 14h |  |
| 78 | 3.2.3.1 | AR datapackage delivery | milestone | 0d? | 2018-11-09 | 2018-11-09 | 193 |  |  | 2018-10-01 | 2018-10-01 | 0d? | 163.29d |  | start no earlier than 2018-11-09 |  |  |  |
| 79 | 3.2.3.2 | AR Kick Off Meeting | milestone | 1d? | 2019-06-15 | 2019-06-15 | 78FS+15d |  |  | 2017-11-28 | 2017-11-28 | 1d? | 0d |  | must start on 2019-06-15 |  |  |  |
| 80 | 3.2.3.3 | AR Reviewers feedback |  | 7d? | 2019-06-17 | 2019-06-25 | 79FS+1d |  |  | 2017-12-14 | 2017-12-19 | 4d? | 188.29d | 0d | start no earlier than 2017-05-31 |  |  |  |
| 81 | 3.2.3.4 | AR ROC response |  | 2d? | 2019-06-25 | 2019-06-27 | 80 |  |  | 2017-12-11 | 2017-12-12 | 2d? | 188.29d | 0d |  |  | 14h |  |
| 82 | 3.2.3.5 | AR question/answer discussion | milestone | 0d? | 2019-07-01 | 2019-07-01 | 81FS+2d |  |  | 2017-12-14 | 2017-12-14 | 0d? | 188.29d | 0d |  |  |  |  |
| 83 | 3.2.3.6 | AR final report release | milestone | 0d | 2019-07-01 | 2019-07-01 | 82 |  |  |  |  |  | 296.86d |  |  |  |  |  |
| 84 | 4 | **ROC SOFTWARE DEVELOPMENT** |  | 1638.71d? | 2014-01-01 A | 2019-06-28 |  | 61% | 635.52d? | 2014-01-01 | 2026-02-09 | 3610.43d | 297.29d |  |  |  | 18140.3h | 12008.6h |
| 85 | 4.1 | **Conceptual design phase** |  | 222.43d | 2016-05-02 A | 2017-01-27 A |  | 100% |  | 2017-01-19 | 2026-02-09 | 2700.71d |  |  |  |  | 1609.92h | 1609.92h |
| 86 | 4.1.1 | RDP issue 1 preparation & writing |  | 30d | 2016-05-02 A | 2016-06-07 A |  | 100% |  | 2017-01-19 | 2017-02-07 | 15d |  |  |  | X.Bonnin [85%] | 178.5h | 178.5h |
| 87 | 4.1.2 | RSSS issue 1 preparation & writing |  | 20.71d | 2016-09-05 A | 2016-09-29 A | 86 | 100% |  | 2020-01-21 | 2020-02-07 | 15d |  |  |  | X.Bonnin [85%] | 123.25h | 123.25h |
| 88 | 4.1.3 | RCS ICD issue 1 preparation & writing |  | 11d | 2016-10-03 A | 2016-10-14 A | 87 | 100% |  | 2023-01-20 | 2023-01-24 | 3d |  |  |  | X.Bonnin [85%] | 65.45h | 65.45h |
| 89 | 4.1.4 | RSSDD issue 1 preparation & writing |  | 44.71d | 2016-10-17 A | 2016-12-09 A | 87, 88 | 100% |  | 2026-01-21 | 2026-02-09 | 15d |  |  |  | S.Lion; X.Bonnin [85%] | 579.05h | 579.05h |
| 90 | 4.1.5 | MDBDD issue 1 preparation & writing |  | 55.57d | 2016-10-17 A | 2016-12-22 A | 87 | 100% |  | 2023-01-20 | 2023-01-24 | 3d |  |  |  | X.Bonnin [85%] | 330.65h | 330.65h |
| 91 | 4.1.6 | RPW LLVM DD issue 1 preparation & writing |  | 47.57d | 2016-12-01 A | 2017-01-27 A | 87 | 100% |  | 2023-01-20 | 2023-01-24 | 3d |  |  |  | S.Lion | 333.02h | 333.02h |
| 92 | 4.2 | **RSS** |  | 1638.71d? | 2014-01-01 A | 2019-06-28 |  | 58% | 688.01d? | 2014-01-01 | 2019-06-28 | 1638.71d | 297.29d |  |  |  | 16530.3h | 10398.7h |
| 93 | 4.2.1 | **RSS0: "Preliminary" release** |  | 495.86d | 2014-01-01 A | 2015-08-31 A |  | 100% |  |  |  |  |  |  |  |  | 2138h | 2138h |
| 94 | 4.2.1.1 | **ROC GSE** |  | 493.71d | 2014-01-01 A | 2015-08-28 A |  | 100% |  |  |  |  |  |  |  |  | 1998h | 1998h |
| 95 | 4.2.1.1.1 | **SAVS** |  | 195.43d | 2015-01-01 A | 2015-08-28 A |  | 100% |  |  |  |  |  |  |  |  | 1368h | 1368h |
| 96 | 4.2.1.1.1.1 | **SimuSBM1 V1** |  | 195.43d | 2015-01-01 A | 2015-08-28 A |  | 100% |  | 2015-01-01 | 2018-05-25 | 1012.43d |  |  |  |  | 342h | 342h |
| 97 | 4.2.1.1.1.1.1 | SimuSBM1 V1 development & validation test |  | 195.43d | 2015-01-01 A | 2015-08-28 A |  | 100% |  | 2015-01-01 | 2015-08-28 | 195.43d |  |  | start no earlier than 2015-01-01 | X.Bonnin [25%]; M.Maksimvovic | 342h | 342h |
| 98 | 4.2.1.1.1.2 | **SimuSBM2 V1** |  | 195.43d | 2015-01-01 A | 2015-08-28 A |  | 100% |  | 2015-01-01 | 2018-09-26 | 1113.57d |  |  |  |  | 1026h | 1026h |
| 99 | 4.2.1.1.1.2.1 | SimuSBM2 V1 development & validation test |  | 195.43d | 2015-01-01 A | 2015-08-28 A |  | 100% |  | 2015-01-01 | 2015-08-28 | 195.43d |  |  | start no earlier than 2015-01-01 | X.Bonnin [25%]; M.Maksimvovic [25%]; O.Alexandrova [25%] | 1026h | 1026h |
| 100 | 4.2.1.1.2 | **ROC-SGSE** |  | 90d | 2014-01-01 A | 2014-04-21 A |  | 100% |  |  |  |  |  |  |  |  | 630h | 630h |
| 101 | 4.2.1.1.2.1 | RPL 0.1.0 |  | 90d | 2014-01-01 A | 2014-04-21 A |  | 100% |  |  |  |  |  |  |  | T.Sauzière | 630h | 630h |

Notes:
- 77: ESA does not planned formal ground segment acceptance review (AR) for payload. Nevertheless, CNES and ROC might planned a kind of AR before the launch. / Date and details are TBD
- 78: ROC End of Design Key Point (EDKP) Deliverables / ———— / Requirements / - ROC Concept & Implementation Requirements Document (CIRD) / - ROC Human-Machine Interfaces User Requirements (HMIUR) / Plans / - ROC Project Management Plan (PMP) / - ROC Software Development Plan (SDP) / - ROC Operations Management Plan (OMP) / - ROC Software Product Assurance Plan (SDAP) / - ROC Validation Plan (RVP) / Specification & Design / - ROC Software System Specification (RSSS) / - ROC Software System Design Document (RSSDD) / - ROC Mission Database Description Document (MDBDD) / - RPW Low Latency Virtual Machine Design Document (LLVMDD) / ICD / - RPW Calibration Software ICD (RCSICD) / - BIAS operations ICD (BOICD) / NTT / - RPW Data Products (RDP) / - Dataset Description Document for RPW Low Latency CDF Files (DDDRLLCF) / - ROC Engineering Guidelines (REG) / - ROC Engineering Guidelines for External Users (REGU) / - Software Configuration File / - Software Reuse File / Planning / - ROC development planning / Matrix / - Traceability Matrix
- 82: Might be a telecon

| ID | WBS | Task | Type | Duration | Start | Finish | Predecessors | Complete | Remaining | Baseline start | Baseline finish | Baseline duration | Total slack | Constraint | Resources | Work | Actual work |
| --- | --- | --- | --- | --- | --- | --- | --- | --- | --- | --- | --- | --- | --- | --- | --- | --- | --- |
| 102 | 4.2.1.2 | **ROADS** |  | 20d | 2014-05-28 A | 2014-06-20 A |  | 100% |  |  |  |  |  |  |  | 140h | 140h |
| 103 | 4.2.1.2.1 | **MUSIC** |  | 20d | 2014-05-28 A | 2014-06-20 A |  | 100% |  |  |  |  |  |  |  | 140h | 140h |
| 104 | 4.2.1.2.1.1 | TRAC 0.1.0 |  | 20d | 2014-05-28 A | 2014-06-20 A | 101 | 100% |  |  |  |  |  | start no earlier than 2014-01-01 | T.Sauzière | 140h | 140h |
| 105 | 4.2.1.3 | RSS0 datapackage delivery | milestone | 0d | 2015-08-31 A | 2015-08-31 A | 97, 99, 104 | 100% |  | 2015-08-31 | 2015-08-31 | 0d? |  | must finish on 2015-08-31 |  |  |  |
| 106 | 4.2.2 | **RSS1: "EM2 calibrations" release** |  | 438.71d | 2014-09-10 A | 2016-03-01 A |  | 100% |  |  |  |  |  |  |  | 3390.47h | 3390.47h |
| 107 | 4.2.2.1 | **ROC GSE** |  | 437.71d | 2014-09-10 A | 2016-02-29 A |  | 100% |  |  |  |  |  |  |  | 3211.97h | 3211.97h |
| 108 | 4.2.2.1.1 | **ROC-SGSE V1** |  | 437.71d | 2014-09-10 A | 2016-02-29 A |  | 100% |  |  |  |  |  |  |  | 3211.97h | 3211.97h |
| 109 | 4.2.2.1.1.1 | ROC-SGSE Test database (TDB) design |  | 23.53d | 2014-09-10 A | 2014-10-08 A |  | 100% |  |  |  |  |  | start no earlier than 2014-09-10 | X.Bonnin [85%] | 140h | 140h |
| 110 | 4.2.2.1.1.2 | RPL V0.2.0 development & integration into the ROC-SGSE & tests |  | 130.28d | 2015-09-01 A | 2016-02-05 A | 101, 109 | 100% |  | 2014-01-27 | 2014-07-04 | 130.28d |  |  | E.Holle; M.Duarte | 911.97h | 911.97h |
| 111 | 4.2.2.1.1.3 | ROC-SGSE V1 development & tests |  | 308.57d | 2015-02-16 A | 2016-02-29 A | 110 | 100% |  | 2015-02-16 | 2016-02-29 | 308.57d |  | must start on 2015-02-16 | M.Duarte | 2160h | 2160h |
| 112 | 4.2.2.2 | **ROADS** |  | 30d | 2015-11-02 A | 2015-12-08 A |  | 100% |  |  |  |  |  |  |  | 178.5h | 178.5h |
| 113 | 4.2.2.2.1 | **LLVM** |  | 30d | 2015-11-02 A | 2015-12-08 A |  | 100% |  |  |  |  |  |  |  | 178.5h | 178.5h |
| 114 | 4.2.2.2.1.1 | "Hello World" version development & tests |  | 30d | 2015-11-02 A | 2015-12-08 A |  | 100% |  | 2014-01-01 | 2016-02-24 | 640d |  | start no earlier than 2015-11-02 | X.Bonnin [85%] | 178.5h | 178.5h |
| 115 | 4.2.2.3 | RSS1 datapackage delivery | milestone | 0d | 2016-03-01 A | 2016-03-01 A | 111, 114 | 100% |  | 2016-03-01 | 2016-03-01 | 0d |  | must start on 2016-03-01 |  |  |  |
| 116 | 4.2.3 | **RSS2: "PFM calibrations release"** |  | 196.38d | 2016-04-18 A | 2016-12-13 A |  | 100% |  |  |  |  |  |  |  | 2784h | 2784h |
| 117 | 4.2.3.1 | **ROC GSE** |  | 196.38d | 2016-04-18 A | 2016-12-13 A |  | 100% |  |  |  |  |  |  |  | 2784h | 2784h |
| 118 | 4.2.3.1.1 | **ROC-SGSE V2** |  | 196.38d | 2016-04-18 A | 2016-12-13 A |  | 100% |  | 2016-03-02 | 2016-11-02 | 199.86d |  |  |  | 2784h | 2784h |
| 119 | 4.2.3.1.1.1 | ROC-SGSE V2 development & tests |  | 196.38d | 2016-04-18 A | 2016-12-13 A | 111 | 100% |  | 2016-03-02 | 2016-11-01 | 198.86d? |  | start no earlier than 2016-04-18 | M.Duarte; X.Bonnin [85%] | 2784h | 2784h |
| 120 | 4.2.3.2 | RSS2 datapackage delivery | milestone | 0d | 2016-11-02 A | 2016-11-02 A | 119, 213, 218, 223, 228, 233 | 100% |  | 2016-11-02 | 2016-11-02 | 0d |  | must start on 2016-11-02 |  |  |  |
| 121 | 4.2.4 | **RSS3: "E2E test" release** |  | 570.43d? | 2016-02-25 A | 2018-01-24 |  | 63% | 208.5d? | 2014-01-01 | 2018-01-18 | 1206.86d | 179.43d |  |  | 3159h | 2033.75h |
| 122 | 4.2.4.1 | RSS developement/testing environments setup, including integration tools (Jenkins, Gitlab) |  | 10d | 2016-10-03 A | 2016-10-13 A |  | 100% |  | 2016-10-03 | 2016-10-13 | 10d |  | start no earlier than 2016-10-03 | S.Lion | 70h | 70h |
| 123 | 4.2.4.2 | **ROADS** |  | 570.43d? | 2016-02-25 A | 2018-01-24 |  | 63% | 213.36d? |  |  |  | 179.43d |  |  | 3089h | 1963.75h |
| 124 | 4.2.4.2.1 | **MUSIC** |  | 229.86d? | 2017-04-18 A | 2018-01-24 |  | 52% | 109.45d? |  |  |  | 724.43d |  |  | 1617h | 847h |
| 125 | 4.2.4.2.1.1 | **FIGARO** |  | 86.86d | 2017-04-18 A | 2017-08-02 A |  | 100% |  |  |  |  |  |  |  | 616h | 616h |
| 126 | 4.2.4.2.1.1.1 | View list of procedures |  | 33d | 2017-04-18 A | 2017-05-26 A | 122 | 100% |  |  |  |  |  | start no earlier than 2017-04-18 | A.Aboubacar | 231h | 231h |
| 127 | 4.2.4.2.1.1.2 | Import procedure in Excel format |  | 22d | 2017-05-26 A | 2017-06-22 A | 126 | 100% |  |  |  |  |  |  | A.Aboubacar | 154h | 154h |
| 128 | 4.2.4.2.1.1.3 | Validate procedure model |  | 33d | 2017-06-22 A | 2017-08-02 A | 127 | 100% |  |  |  |  |  |  | A.Aboubacar | 231h | 231h |

| ID | WBS | Task | Type | Duration | Start | Finish | Predecessors | Complete | Remaining | Baseline start | Baseline finish | Baseline duration | Total slack | Free slack | Constraint | Resources | Work | Actual work |
| --- | --- | --- | --- | --- | --- | --- | --- | --- | --- | --- | --- | --- | --- | --- | --- | --- | --- | --- |
| 129 | 4.2.4.2.1.2 | **FAUST** |  | 99d? | 2017-08-02 A | 2017-11-30 |  | 33% | 66d? |  |  |  | 768.43d |  |  |  | 693h | 231h |
| 130 | 4.2.4.2.1.2.1 | View list of MTP IOR |  | 44d? | 2017-08-02 A | 2017-09-25 | 128 | 25% | 33d? |  |  |  | 823.43d |  |  | A.Aboubacar | 308h | 77h |
| 131 | 4.2.4.2.1.2.2 | Create new MTP IOR |  | 44d? | 2017-09-25 A | 2017-11-17 | 130 | 50% | 22d? |  |  |  | 724.43d | 0d |  | A.Aboubacar | 308h | 154h |
| 132 | 4.2.4.2.1.2.3 | Generate MTP/STP IOR data package to be delivered at SOC |  | 11d? | 2017-11-17 | 2017-11-30 | 131 |  |  |  |  |  | 724.43d | 0d |  | A.Aboubacar | 77h |  |
| 133 | 4.2.4.2.1.3 | **OPERA** |  | 44d? | 2017-11-30 | 2018-01-24 |  |  |  |  |  |  | 724.43d |  |  |  | 308h |  |
| 134 | 4.2.4.2.1.3.1 | View E-FECS |  | 22d? | 2017-11-30 | 2017-12-27 | 132 |  |  |  |  |  | 724.43d | 0d |  | A.Aboubacar | 154h |  |
| 135 | 4.2.4.2.1.3.2 | View TMC view |  | 22d? | 2017-12-28 | 2018-01-24 | 134 |  |  |  |  |  | 724.43d |  |  | A.Aboubacar | 154h |  |
| 136 | 4.2.4.2.2 | **RODP** |  | 364.37d? | 2016-11-02 A | 2018-01-22 |  | 69% | 112.56d? |  |  |  | 726.06d |  |  |  | 919h | 660h |
| 137 | 4.2.4.2.2.1 | Initial migration from ROC-SGSE V2 code source |  | 74.29d | 2016-11-02 A | 2017-01-31 A | 120, 122 | 100% |  | 2016-03-22 | 2016-06-21 | 74.29d? |  |  | start no earlier than 2016-10-03 | S.Lion | 520h | 520h |
| 138 | 4.2.4.2.2.2 | POPPy framework upgrade |  | 30d? | 2017-11-07 A | 2017-12-13 | 137 | 33% | 20d? | 2017-11-07 | 2017-11-08 | 1d? | 758.06d |  |  | G.Duvauchelle | 210h | 70h |
| 139 | 4.2.4.2.2.3 | RODP install manager |  | 20d? | 2017-12-13 A | 2018-01-08 | 138 | 50% | 10d? | 2017-11-08 | 2017-11-09 | 1d? | 726.06d | 0d |  | G.Duvauchelle | 140h | 70h |
| 140 | 4.2.4.2.2.4 | E-FECS, TMC data import |  | 1d? | 2018-01-08 | 2018-01-09 | 139 |  |  |  |  |  | 726.06d | 0d |  | X.Bonnin | 7h |  |
| 141 | 4.2.4.2.2.5 | Data distribution to/from file systems |  | 1d? | 2018-01-09 | 2018-01-10 | 140 |  |  |  |  |  | 726.06d | 0d |  | X.Bonnin | 7h |  |
| 142 | 4.2.4.2.2.6 | CAWA RCS interface validation tool |  | 10d? | 2018-01-10 | 2018-01-22 | 141 |  |  | 2017-11-07 | 2017-11-20 | 10d? | 726.06d |  | start no earlier than 2017-10-03 | Q.N.Nguyen [50%] | 35h |  |
| 143 | 4.2.4.2.3 | **LLVM** |  | 523.14d | 2016-02-25 A | 2017-11-27 |  | 75% | 130.79d |  |  |  | 179.43d |  |  |  | 105h | 78.75h |
| 144 | 4.2.4.2.3.1 | "Processing" version development & tests |  | 0d | 2016-02-25 A | 2016-03-02 | 34 | 75% | 0d | 2016-02-25 | 2016-03-21 | 20d | 174.43d | 482.86d | must start on 2016-10-03 | S.Lion | 35h | 26.25h |
| 145 | 4.2.4.2.3.2 | "Processing + test" version development & tests |  | 10d | 2017-11-15 A | 2017-11-27 | 37 | 75% | 2.5d | 2017-11-15 | 2017-11-27 | 10d | 771.71d | 12.71d |  | S.Lion | 70h | 52.5h |
| 146 | 4.2.4.2.4 | **MDB** |  | 271.71d? | 2016-11-02 A | 2017-09-29 |  | 89% | 30.91d? | 2016-11-02 | 2017-11-07 | 302.37d | 818.71d |  |  |  | 448h | 378h |
| 147 | 4.2.4.2.4.1 | Initial migration from TDB |  | 4.7d | 2016-11-02 A | 2016-11-08 A | 120 | 100% |  | 2016-11-02 | 2016-11-21 | 16d |  |  |  | X.Bonnin [85%] | 28h | 28h |
| 148 | 4.2.4.2.4.2 | RODP model design |  | 23.53d | 2017-07-07 A | 2017-08-04 A | 147 | 100% |  | 2017-01-02 | 2017-11-07 | 30d? |  |  | start no earlier than 2017-07-07 | X.Bonnin [85%] | 140h | 140h |
| 149 | 4.2.4.2.4.3 | MUSIC model design |  | 23.57d? | 2017-09-01 A | 2017-09-29 | 147 | 75% | 5.93d? | 2017-10-03 | 2017-10-26 | 20d? | 818.71d |  | start no earlier than 2017-09-01 | S.Lion; X.Bonnin [85%] | 280h | 210h |
| 150 | 4.2.4.3 | RSS3 datapackage delivery | milestone | 0d | 2017-12-15 | 2017-12-15 | 214, 219, 224, 229, 234 |  |  | 2017-12-15 | 2017-12-15 | 0d | 0d |  | must finish on 2017-12-15 |  |  |  |
| 151 | 4.2.5 | **RSS4: "Ready-for-flight" release** |  | 234.29d? | 2017-12-18 A | 2018-09-28 | 150 | 1% | 232.97d? | 2017-12-18 | 2018-10-17 | 249.14d | 215.29d |  |  |  | 2946.98h | 52.5h |
| 152 | 4.2.5.1 | **ROC GSE** |  | 15d? | 2018-04-02 | 2018-04-19 |  |  |  | 2014-01-01 | 2018-09-26 | 1411.86d | 133.57d |  |  |  | 105h |  |
| 153 | 4.2.5.1.1 | **ROC-SGSE** |  | 15d? | 2018-04-02 | 2018-04-19 |  |  |  | 2014-01-01 | 2018-09-26 | 1411.86d | 133.57d |  |  |  | 105h |  |
| 154 | 4.2.5.1.1.1 | ROC-SGSE V2 instance deployement for mission |  | 15d? | 2018-04-02 | 2018-04-19 | 119 |  |  | 2018-09-03 | 2018-09-26 | 20d? | 133.57d |  | start no earlier than 2018-04-01 | X.Bonnin [85%] | 105h |  |

Notes:
- 150: The ROADS « E2E test» datapackage to be delivered prior to the E2E test campaign organized by the SOC/MOC / The content is TBD
- 154: Exact date is TBC

| ID | WBS | Task | Duration | Start | Finish | Predecessors | Complete | Remaining | Baseline start | Baseline finish | Baseline duration | Total slack | Free slack | Constraint | Resources | Work | Actual work |
| --- | --- | --- | --- | --- | --- | --- | --- | --- | --- | --- | --- | --- | --- | --- | --- | --- | --- |
| 155 | 4.2.5.2 | **ROADS** | 160d? | 2017-12-18 A | 2018-06-29 |  | 1% | 159.08d? |  |  |  | 215.29d |  |  |  | 2841.98h | 52.5h |
| 156 | 4.2.5.2.1 | ROADS MOC secondary instances development | 20d | 2018-06-06 | 2018-06-29 | 150, 157, 175 |  |  |  |  |  | 595.57d |  | start no earlier than 2018-05-01 | S.Lion; X.Bonnin [85%] | 259h |  |
| 157 | 4.2.5.2.2 | **RODP** | 140d? | 2017-12-18 | 2018-06-06 |  |  |  | 2017-12-18 | 2018-01-23 | 30d | 615.57d | 0d |  |  | 1050h |  |
| 158 | 4.2.5.2.2.1 | LZ, L0, L1/HK-digest data production | 1d? | 2017-12-18 | 2017-12-18 |  |  |  |  |  |  | 734.57d |  |  | CDD IE2 (TBD) | 7h |  |
| 159 | 4.2.5.2.2.2 | L0 data production | 1d? | 2017-12-18 | 2017-12-18 |  |  |  |  |  |  | 734.57d |  |  | CDD IE2 (TBD) | 7h |  |
| 160 | 4.2.5.2.2.3 | **L1 CDF data production** | 1d? | 2017-12-18 | 2017-12-18 |  |  |  |  |  |  | 754.57d |  |  |  | 28h |  |
| 161 | 4.2.5.2.2.3.1 | Science L1 CDF | 1d? | 2017-12-18 | 2017-12-18 |  |  |  |  |  |  | 754.57d |  |  | CDD IE2 (TBD) | 7h |  |
| 162 | 4.2.5.2.2.3.2 | BP1/BP2 decommutation for L1 CDF | 1d? | 2017-12-18 | 2017-12-18 |  |  |  |  |  |  | 754.57d |  |  | CDD IE2 (TBD) | 7h |  |
| 163 | 4.2.5.2.2.3.3 | Bias sweep CDF | 1d? | 2017-12-18 | 2017-12-18 |  |  |  |  |  |  | 754.57d |  |  | CDD IE2 (TBD) | 7h |  |
| 164 | 4.2.5.2.2.3.4 | HFR L1 LIST MODE | 1d? | 2017-12-18 | 2017-12-18 |  |  |  |  |  |  | 754.57d |  |  | CDD IE2 (TBD) | 7h |  |
| 165 | 4.2.5.2.2.4 | **HK CDF production** | 1d? | 2017-12-18 | 2017-12-18 |  |  |  |  |  |  | 754.57d |  |  |  | 7h |  |
| 166 | 4.2.5.2.2.4.1 | HK engineering values in CDF | 1d? | 2017-12-18 | 2017-12-18 |  |  |  |  |  |  | 754.57d |  |  | CDD IE2 (TBD) | 7h |  |
| 167 | 4.2.5.2.2.5 | RCS calling by CAWA | 1d? | 2017-12-18 | 2017-12-18 |  |  |  |  |  |  | 734.57d |  |  | CDD IE2 (TBD) | 7h |  |
| 168 | 4.2.5.2.2.6 | Summary plots generation | 1d? | 2017-12-18 | 2017-12-18 |  |  |  |  |  |  | 734.57d |  |  | CDD IE2 (TBD) | 7h |  |
| 169 | 4.2.5.2.2.7 | LZ/L0/L1/HK-digest, L2, ancillary and summary plots pre-post validation | 40d? | 2017-12-18 | 2018-02-02 | 150 |  |  | 2017-12-18 | 2018-01-23 | 30d? | 695.57d | 0d | start no earlier than 2017-10-03 | CDD IE2 (TBD) | 280h |  |
| 170 | 4.2.5.2.2.8 | MONA - Data monitoring (TC verif.,) | 30d? | 2018-02-05 | 2018-03-13 | 169 |  |  |  |  |  | 665.57d | 0d |  | CDD IE2 (TBD) | 210h |  |
| 171 | 4.2.5.2.2.9 | DDS client (to retrieve TM) | 1d? | 2017-12-18 | 2017-12-18 |  |  |  |  |  |  | 734.57d |  |  | CDD IE2 (TBD) | 7h |  |
| 172 | 4.2.5.2.2.10 | Automated Event Notification system | 10d? | 2018-03-13 | 2018-03-23 | 170 |  |  |  |  |  | 655.57d | 0d |  | CDD IE2 (TBD) | 70h |  |
| 173 | 4.2.5.2.2.11 | RPW preliminary/definitive data distribution system | 30d? | 2018-03-26 | 2018-05-01 | 172 |  |  | 2017-12-18 | 2017-12-18 | 1d? | 625.57d | 0d |  | CDD IE2 (TBD) | 210h |  |
| 174 | 4.2.5.2.2.12 | RPW data archiving system (ESAC) | 30d? | 2018-05-01 | 2018-06-06 | 173 |  |  | 2017-12-18 | 2017-12-18 | 1d? | 595.57d |  |  | CDD IE2 (TBD) | 210h |  |
| 175 | 4.2.5.2.3 | **MUSIC** | 120d? | 2017-12-18 A | 2018-05-11 |  | 1% | 119.07d? | 2017-12-18 | 2018-10-17 | 249.14d | 215.29d | 20d |  |  | 1532.98h | 52.5h |
| 176 | 4.2.5.2.3.1 | INCA module development | 120d | 2017-12-18 | 2018-05-11 | 122 |  |  | 2017-12-18 | 2018-01-23 | 30d | 615.57d |  | start no earlier than 2017-10-03 | S.Lion [10%] | 84h |  |
| 177 | 4.2.5.2.3.2 | TRAC module development | 120d? | 2017-12-18 | 2018-05-11 | 122 |  |  | 2017-12-18 | 2018-10-17 | 249.14d? | 615.57d |  | start no earlier than 2017-10-03 | N.Fuller [20%] | 168h |  |
| 178 | 4.2.5.2.3.3 | POCA module development | 120d? | 2017-12-18 | 2018-05-11 | 122 |  |  | 2017-12-18 | 2018-04-16 | 98.29d? | 615.57d |  | start no earlier than 2017-10-03 | N.Fuller [20%] | 168h |  |

| ID | WBS | Task | Type | Duration | Start | Finish | Predecessors | Complete | Remaining | Baseline start | Baseline finish | Baseline duration | Total slack | Free slack | Constraint | Resources | Work | Actual work |
| --- | --- | --- | --- | --- | --- | --- | --- | --- | --- | --- | --- | --- | --- | --- | --- | --- | --- | --- |
| 179 | 4.2.5.2.3.4 | **TV** |  | 75d? | 2017-12-18 | 2018-03-19 |  |  |  | 2017-12-18 | 2017-12-18 | 1d | 233.29d |  |  |  | 532h |  |
| 180 | 4.2.5.2.3.4.1 | Displaying events |  | 15d? | 2017-12-18 | 2018-01-04 | 150 |  |  | 2017-12-18 | 2017-12-18 | 1d? | 680.57d | 0d |  | S.Lion | 105h |  |
| 181 | 4.2.5.2.3.4.2 | Displaying status |  | 30d? | 2018-01-04 | 2018-02-09 | 180 |  |  | 2017-12-18 | 2017-12-18 | 1d? | 680.57d | 0d |  | S.Lion | 210h |  |
| 182 | 4.2.5.2.3.4.3 | Displaying HK |  | 30d? | 2018-02-09 | 2018-03-19 | 181 |  |  | 2017-12-18 | 2017-12-18 | 1d? | 680.57d |  |  | S.Lion | 210h |  |
| 183 | 4.2.5.2.3.4.4 | Displaying science |  | 1d? | 2017-12-18 | 2017-12-18 |  |  |  |  |  |  | 233.29d |  |  | S.Lion | 7h |  |
| 184 | 4.2.5.2.3.5 | **FIGARO** |  | 15d? | 2017-12-18 A | 2018-01-04 |  | 25% | 11.25d? | 2017-12-18 | 2017-12-18 | 1d | 219.29d |  |  |  | 210h | 52.5h |
| 185 | 4.2.5.2.3.5.1 | Procedure edition |  | 15d? | 2017-12-18 A | 2018-01-04 | 150 | 25% | 11.25d? | 2017-12-18 | 2017-12-18 | 1d? | 219.29d |  |  | A.Aboubacar; S.Lion | 210h | 52.5h |
| 186 | 4.2.5.2.3.6 | **FAUST** |  | 19d? | 2017-12-18 | 2018-01-09 |  |  |  | 2017-12-18 | 2017-12-18 | 1d | 215.29d |  |  |  | 265.98h |  |
| 187 | 4.2.5.2.3.6.1 | MDOR/PDOR format handling implementation |  | 3.5d? | 2017-12-18 | 2017-12-21 | 150 |  |  | 2017-12-18 | 2017-12-18 | 1d? | 215.29d | 0d |  | A.Aboubacar; S.Lion | 49h |  |
| 188 | 4.2.5.2.3.6.2 | MEB C-SGSE script format import/export |  | 15d? | 2017-12-21 | 2018-01-09 | 187 |  |  | 2017-12-18 | 2017-12-18 | 1d? | 215.29d | 0d |  | A.Aboubacar; S.Lion | 210h |  |
| 189 | 4.2.5.2.3.6.3 | TMC/PW constraints visualization |  | 0.5d? | 2018-01-09 | 2018-01-09 | 188 |  |  |  |  |  | 215.29d |  |  | A.Aboubacar; S.Lion | 6.98h |  |
| 190 | 4.2.5.2.3.7 | **SISSI** |  | 15d? | 2017-12-18 | 2018-01-04 |  |  |  | 2017-12-18 | 2017-12-18 | 1d | 219.29d |  |  |  | 105h |  |
| 191 | 4.2.5.2.3.7.1 | SBM event visualization |  | 15d? | 2017-12-18 | 2018-01-04 | 150 |  |  | 2017-12-18 | 2017-12-18 | 1d? | 219.29d |  |  | A.Aboubacar | 105h |  |
| 192 | 4.2.5.3 | RSS4 datapackage pre-delivery for validation campaign | milestone | 0d | 2018-09-28 | 2018-09-28 | 154, 183, 185, 189, 191, 397, 398 |  |  | 2018-09-28 | 2018-09-28 | 0d | 0d |  | must finish on 2018-09-28 |  |  |  |
| 193 | 4.2.5.4 | RSS4 datapackage delivery | milestone | 0d | 2018-09-28 | 2018-09-28 | 253 |  |  |  |  |  | 0d |  | must finish on 2018-09-28 |  |  |  |
| 194 | 4.2.6 | **RSS5: "Fully operational" release** |  | 348.57d? | 2018-05-01 | 2019-06-28 |  |  |  | 2019-02-25 | 2019-06-28 | 104d | 222.43d |  |  |  | 2111.9h |  |
| 195 | 4.2.6.1 | **ROC GSE** |  | 161.71d? | 2018-05-01 | 2018-11-14 |  |  |  |  |  |  | 484.14d |  |  |  | 420h |  |
| 196 | 4.2.6.1.1 | **SAVS** |  | 161.71d? | 2018-05-01 | 2018-11-14 |  |  |  |  |  |  | 484.14d |  |  |  | 420h |  |
| 197 | 4.2.6.1.1.1 | **SimuSBM1 V2** |  | 60d? | 2018-05-01 | 2018-07-12 |  |  |  | 2018-05-01 | 2018-05-25 | 20.57d | 585.86d |  |  |  | 210h |  |
| 198 | 4.2.6.1.1.1.1 | SimuSBM1 V2 development & validation test |  | 60d? | 2018-05-01 | 2018-07-12 | 97 |  |  | 2018-05-01 | 2018-05-24 | 20d? | 585.86d |  | start no earlier than 2018-05-01 | A.Vecchio [50%] | 210h |  |
| 199 | 4.2.6.1.1.2 | **SimuSBM2 V2** |  | 60d? | 2018-09-03 | 2018-11-14 |  |  |  | 2018-09-03 | 2018-09-26 | 20d | 484.14d |  |  |  | 210h |  |
| 200 | 4.2.6.1.1.2.1 | SimuSBM2 V2 development & validation test |  | 60d? | 2018-09-03 | 2018-11-14 | 99 |  |  | 2018-09-03 | 2018-09-26 | 20d? | 484.14d |  | start no earlier than 2018-09-03 | A.Vecchio [50%] | 210h |  |
| 201 | 4.2.6.2 | **ROADS** |  | 33d? | 2018-09-28 | 2018-11-08 |  |  |  |  |  |  | 98d |  |  |  | 752.5h |  |
| 202 | 4.2.6.2.1 | **MUSIC** |  | 33d? | 2018-09-28 | 2018-11-08 |  |  |  |  |  |  | 98d |  |  |  | 693h |  |
| 203 | 4.2.6.2.1.1 | **FAUST** |  | 33d? | 2018-09-28 | 2018-11-08 |  |  |  |  |  |  | 98d |  |  |  | 462h |  |
| 204 | 4.2.6.2.1.1.1 | ISM visualization |  | 33d? | 2018-09-28 | 2018-11-08 | 193 |  |  |  |  |  | 98d |  |  | A.Aboubacar; S.Lion | 462h |  |

Notes:
- 186: The FAUST tool may be developped from the source code of the IOR editor of the EUI team (TBC)
- 190: Exact spec concerning the SISSI tool interface with SOC are not known. / Since the SBM1/SBM2 selective downlink will not be operational during the CP (cf. SOC). We propose that this tool is not a high priority for the NECP/CP. / Testing and final delivery should be planned during the CP (TBC).
- 192: The ROADS « ready for flight » version is to be delivered after the TRB and prior to the AR (TBD)

| ID | WBS | Task | Type | Duration | Start | Finish | Predecessors | Complete | Baseline start | Baseline finish | Baseline duration | Total slack | Free slack | Constraint | Resources | Work |
| --- | --- | --- | --- | --- | --- | --- | --- | --- | --- | --- | --- | --- | --- | --- | --- | --- |
| 205 | 4.2.6.2.1.2 | **SISSI** |  | 33d | 2018-09-28 | 2018-11-08 |  |  |  |  |  | 98d |  |  |  | 231h |
| 206 | 4.2.6.2.1.2.1 | SBM event data selection |  | 33d | 2018-09-28 | 2018-11-08 | 193 |  |  |  |  | 98d |  |  | A.Aboubacar | 231h |
| 207 | 4.2.6.2.2 | **RODP** |  | 8.5d? | 2018-09-28 | 2018-10-10 |  |  |  |  |  | 122.5d |  |  |  | 59.5h |
| 208 | 4.2.6.2.2.1 | RPW data archiving (CDPP) |  | 8.5d? | 2018-09-28 | 2018-10-10 | 193 |  |  |  |  | 122.5d |  |  | CDD IE2 (TBD) | 59.5h |
| 209 | 4.2.6.3 | NECP system validation (details TBD) |  | 44d | 2019-03-08 | 2019-05-01 | 54SS, 204, 206, 208 |  | 2019-02-25 | 2019-03-07 | 10d | 0d | 49.14d | finish no later than 2019-05-01 | A.Aboubacar; N.Fuller [20%]; S.Lion; X.Bonnin [85%] | 939.4h |
| 210 | 4.2.6.4 | RSS5 datapackage delivery | milestone | 0d | 2019-06-28 | 2019-06-28 | 209, 216, 221, 226, 231, 236 |  | 2019-06-28 | 2019-06-28 | 0d | 0d | 297.29d | must finish on 2019-06-28 |  |  |
| 211 | 4.3 | **RCS delivery schedule** |  | 744d | 2016-12-15 | 2019-06-14 |  |  | 2016-12-15 | 2019-06-14 | 744d | 299.43d |  |  |  |  |
| 212 | 4.3.1 | **THR_CALBAR** |  | 743.57d | 2016-12-15 | 2019-06-14 |  |  | 2016-12-15 | 2019-06-14 | 743.57d | 299d |  |  |  |  |
| 213 | 4.3.1.1 | Software preliminary version delivery for ROC-SGSE | milestone | 0d | 2016-12-15 A | 2016-12-15 A |  | 100% | 2016-12-15 | 2016-12-15 | 0d |  |  | must finish on 2016-12-15 |  |  |
| 214 | 4.3.1.2 | First "processing" version datapackage delivery | milestone | 0d | 2017-12-15 | 2017-12-15 |  |  | 2017-12-15 | 2017-12-15 | 0d | 1.14d |  | start no earlier than 2017-12-15 |  |  |
| 215 | 4.3.1.3 | "ready for flight" version datapackage delivery | milestone | 0d | 2018-06-15 | 2018-06-15 | 214 |  | 2018-06-15 | 2018-06-15 | 0d | 62.43d | 86.86d | start no earlier than 2018-06-15 |  |  |
| 216 | 4.3.1.4 | "fully operational" version datapackage delivery | milestone | 0d | 2019-06-14 | 2019-06-14 | 215 |  | 2019-06-14 | 2019-06-14 | 0d | 13.71d |  | start no earlier than 2019-06-14 |  |  |
| 217 | 4.3.2 | **TDS_CALBA** |  | 744d | 2016-12-15 | 2019-06-14 |  |  | 2016-12-15 | 2019-06-14 | 744d | 299.43d |  |  |  |  |
| 218 | 4.3.2.1 | Software preliminary version delivery for ROC-SGSE | milestone | 0d | 2016-12-15 A | 2016-12-15 A |  | 100% | 2016-12-15 | 2016-12-15 | 0d |  |  | start no earlier than 2016-12-15 |  |  |
| 219 | 4.3.2.2 | First "processing" version datapackage delivery | milestone | 0d | 2017-12-15 | 2017-12-15 |  |  | 2017-12-15 | 2017-12-15 | 0d | 1.14d |  | start no earlier than 2017-12-15 |  |  |
| 220 | 4.3.2.3 | "ready for flight" version datapackage delivery | milestone | 0d | 2018-06-15 | 2018-06-15 | 219 |  | 2018-06-15 | 2018-06-15 | 0d | 62.43d | 86.86d | start no earlier than 2018-06-15 |  |  |
| 221 | 4.3.2.4 | "fully operational" version datapackage delivery | milestone | 0d | 2019-06-14 | 2019-06-14 | 220 |  | 2019-06-14 | 2019-06-14 | 0d | 13.71d |  | start no earlier than 2019-06-14 |  |  |
| 222 | 4.3.3 | **LFR_CALBUT** |  | 744d | 2016-12-15 | 2019-06-14 |  |  | 2016-12-15 | 2019-06-14 | 744d | 299.43d |  |  |  |  |
| 223 | 4.3.3.1 | Software preliminary version delivery for ROC-SGSE | milestone | 0d | 2016-12-15 A | 2016-12-15 A |  | 100% | 2016-12-15 | 2016-12-15 | 0d |  |  | start no earlier than 2016-12-15 |  |  |
| 224 | 4.3.3.2 | First "processing" version datapackage delivery | milestone | 0d | 2017-12-15 | 2017-12-15 |  |  | 2017-12-15 | 2017-12-15 | 0d | 1.14d |  | start no earlier than 2017-12-15 |  |  |
| 225 | 4.3.3.3 | "ready for flight" version datapackage delivery | milestone | 0d | 2018-06-15 | 2018-06-15 | 224 |  | 2018-06-15 | 2018-06-15 | 0d | 62.43d | 86.86d | start no earlier than 2018-06-15 |  |  |
| 226 | 4.3.3.4 | "fully operational" version datapackage delivery | milestone | 0d | 2019-06-14 | 2019-06-14 | 225 |  | 2019-06-14 | 2019-06-14 | 0d | 13.71d |  | start no earlier than 2019-06-14 |  |  |
| 227 | 4.3.4 | **SCMCAL** |  | 744d | 2016-12-15 | 2019-06-14 |  |  | 2016-12-15 | 2019-06-14 | 744d | 299.43d |  |  |  |  |
| 228 | 4.3.4.1 | Software preliminary version delivery for ROC-SGSE | milestone | 0d | 2016-12-15 A | 2016-12-15 A |  | 100% | 2016-12-15 | 2016-12-15 | 0d |  |  | start no earlier than 2016-12-15 |  |  |
| 229 | 4.3.4.2 | First "processing" version datapackage delivery | milestone | 0d | 2017-12-15 | 2017-12-15 |  |  | 2017-12-15 | 2017-12-15 | 0d | 1.14d |  | start no earlier than 2017-12-15 |  |  |
| 230 | 4.3.4.3 | "ready for flight" version datapackage delivery | milestone | 0d | 2018-06-15 | 2018-06-15 | 229 |  | 2018-06-15 | 2018-06-15 | 0d | 62.43d | 86.86d | start no earlier than 2018-06-15 |  |  |
| 231 | 4.3.4.4 | "fully operational" version datapackage delivery | milestone | 0d | 2019-06-14 | 2019-06-14 | 230 |  | 2019-06-14 | 2019-06-14 | 0d | 13.71d |  | start no earlier than 2019-06-14 |  |  |

Notes:
- 210: ROADS fully operational version to be delivered at the end of the commissioning
- 213: First delivery including source code, preliminary L2R/L2S CDF skeletons and docs. / Main functionalites : / - production of L2R/L2S CDF files from L1 CDF for ROC-SGSE
- 214: including source code + first draft of the user manual + first issue of the SRS / Main functionalities: / - L1->L2S/L2 data processing
- 215: including source code + first issue of the user manual / Main functionalities: / - L1R/L2 data processing / - ROC ICD fully compliance (interface + descriptor + « automated self-tests »)
- 216: Fully validated version
- 218: First delivery including source code, preliminary L2R/L2S CDF skeletons and docs. / Main functionalites : / - production of L2R/L2S CDF files from L1 CDF for ROC-SGSE
- 219: including source code + first draft of the user manual + first issue of the SRS / Main functionalities: / - L1->L2S/L2 data processing / - L1->L1R WF-E & WF-B data processing
- 220: including source code + first issue of the user manual / Main functionalities: / - L1R/L2 data processing / - ROC ICD fully compliance (interface + descriptor + « automated self-tests »)
- 221: Fully validated version
- 223: First delivery including source code, preliminary L2R/L2S CDF skeletons and docs. / Main functionalites : / - production of L2R/L2S CDF files from L1 CDF for ROC-SGSE
- 224: including source code + first draft of the user manual + first issue of the SRS / Main functionalities: / - L1->L2/L2S data processing / - L1->L1R WF-E & WF-B data processing
- 225: including source code + first issue of the user manual / Main functionalities: / - L1R/L2 data processing / - ROC ICD fully compliance (interface + descriptor + « automated self-tests »)
- 226: Fully validated version
- 228: First delivery including source code, preliminary L2S WF-B CDF skeletons and docs. / Main functionalites : / - production of L2S WF-B CDF files from L1 CDF for ROC-SGSE
- 229: including source code + first draft of the user manual + first issue of the SRS / Main functionalities: / - L1R->L2/L2S WF-B data processing
- 230: including source code + first issue of the user manual / Main functionalities: / - L2 WF-B data processing / - ROC ICD fully compliance (interface + descriptor + « automated self-tests »)
- 231: Fully validated version

| ID | WBS | Task | Type | Duration | Start | Finish | Predecessors | Complete | Remaining | Baseline start | Baseline finish | Baseline duration | Total slack | Free slack | Constraint | Resources | Work | Actual work |
| --- | --- | --- | --- | --- | --- | --- | --- | --- | --- | --- | --- | --- | --- | --- | --- | --- | --- | --- |
| 232 | 4.3.5 | **BICAS** |  | 744d | 2016-12-15 | 2019-06-14 |  |  |  | 2016-12-15 | 2019-06-14 | 744d | 299.43d |  |  |  |  |  |
| 233 | 4.3.5.1 | Software preliminary version delivery for ROC-SGSE | milestone | 0d | 2016-12-15 A | 2016-12-15 A |  | 100% |  | 2016-12-15 | 2016-12-15 | 0d |  |  | start no earlier than 2016-12-15 |  |  |  |
| 234 | 4.3.5.2 | First "processing" version datapackage delivery | milestone | 0d | 2017-12-15 | 2017-12-15 |  |  |  | 2017-12-15 | 2017-12-15 | 0d | 1.14d |  | start no earlier than 2017-12-15 |  |  |  |
| 235 | 4.3.5.3 | "ready for flight" version datapackage delivery | milestone | 0d | 2018-06-15 | 2018-06-15 | 234 |  |  | 2018-06-15 | 2018-06-15 | 0d | 62.43d | 86.86d | start no earlier than 2018-06-15 |  |  |  |
| 236 | 4.3.5.4 | "fully operational" version datapackage delivery | milestone | 0d | 2019-06-14 | 2019-06-14 | 235 |  |  | 2019-06-14 | 2019-06-14 | 0d | 13.71d |  | start no earlier than 2019-06-14 |  |  |  |
| 237 | 5 | **RSS VALIDATION** |  | 24.29d? | 2018-10-01 | 2018-10-30 |  |  |  | 2018-07-02 | 2018-09-17 | 63.86d | -24.43d | 0d |  |  | 204.4h |  |
| 238 | 5.1 | **System validation campaign** |  | 24.29d? | 2018-10-01 | 2018-10-30 |  |  |  | 2018-07-02 | 2018-09-17 | 63.86d | -24.43d | 0d |  |  | 204.4h |  |
| 239 | 5.1.1 | **ROC Test Readiness Review (TRR)** |  | 10.29d? | 2018-10-01 | 2018-10-11 |  |  |  | 2018-07-02 | 2018-07-12 | 10.29d | -24.43d | 0d |  |  |  |  |
| 240 | 5.1.1.1 | TRR datapackage delivery | milestone | 1.14d? | 2018-10-01 | 2018-10-01 | 192, 215, 220, 225, 230, 235 |  |  | 2018-07-02 | 2018-07-02 | 1.14d? | -24.43d | 0d | start no earlier than 2018-07-02 |  |  |  |
| 241 | 5.1.1.2 | TRR meeting | milestone | 1.14d? | 2018-10-11 | 2018-10-11 | 240FS+8d |  |  | 2018-07-12 | 2018-07-12 | 1.14d? | -24.43d | 0d | start no earlier than 2018-07-10 |  |  |  |
| 242 | 5.1.2 | **ROC system validation campaign at LESIA** |  | 13d? | 2018-10-12 | 2018-10-29 |  |  |  |  |  |  | -24.43d | 0d |  |  | 204.4h |  |
| 243 | 5.1.2.1 | Installation/deployment tests |  | 1d? | 2018-10-12 | 2018-10-12 | 241 |  |  |  |  |  | -24.43d | 0d |  | A.Aboubacar; S.Lion | 14h |  |
| 244 | 5.1.2.2 | RODP/ROC-SGSE specific specification/desing tests |  | 1d? | 2018-10-12 | 2018-10-15 | 243 |  |  |  |  |  | -24.43d | 0d |  | X.Bonnin [85%] | 5.95h |  |
| 245 | 5.1.2.3 | MUSIC backend specific specification/design tests |  | 1d? | 2018-10-15 | 2018-10-16 | 244 |  |  |  |  |  | -24.43d | 0d |  | A.Vecchio; N.Fuller [20%]; S.Lion | 15.4h |  |
| 246 | 5.1.2.4 | MDB specific specification/design tests |  | 1d? | 2018-10-16 | 2018-10-17 | 245 |  |  |  |  |  | -24.43d | 0d |  | S.Lion; X.Bonnin [85%] | 12.95h |  |
| 247 | 5.1.2.5 | MUSIC front-end specifc tests |  | 2d? | 2018-10-17 | 2018-10-19 | 246 |  |  |  |  |  | -24.43d | 0d |  | A.Aboubacar; S.Lion | 28h |  |
| 248 | 5.1.2.6 | Validation/verification and problem resolving |  | 3d? | 2018-10-19 | 2018-10-23 | 247 |  |  |  |  |  | -24.43d | 0d |  | A.Aboubacar; N.Fuller [20%]; S.Lion; X.Bonnin [85%] | 64.05h |  |
| 249 | 5.1.2.7 | RSS Validation Test Report (VTR) |  | 3d? | 2018-10-23 | 2018-10-26 | 248 |  |  |  |  |  | -24.43d | 0d |  | A.Aboubacar; N.Fuller [20%]; S.Lion; X.Bonnin [85%] | 64.05h |  |
| 250 | 5.1.2.8 | VTR delivery to the TRB reviewers | milestone | 1d | 2018-10-26 | 2018-10-29 | 249 |  |  |  |  |  | -24.43d | 0d |  |  |  |  |
| 251 | 5.1.3 | **ROC Test Review Board (TRB)** |  | 1d? | 2018-10-29 | 2018-10-30 |  |  |  | 2018-09-03 | 2018-09-17 | 11.29d | -24.43d | 0d |  |  |  |  |
| 252 | 5.1.3.1 | TRB datapackage delivery | milestone | 0d? | 2018-10-29 | 2018-10-29 | 250 |  |  | 2018-09-03 | 2018-09-03 | 0d? | -24.43d | 0d | start no earlier than 2018-09-03 |  |  |  |
| 253 | 5.1.3.2 | TRB conclusion meeting |  | 1d | 2018-10-29 | 2018-10-30 | 252 |  |  | 2018-09-17 | 2018-09-17 | 1d | -24.43d | 0d | start no earlier than 2018-09-17 |  |  |  |
| 254 | 6 | **RPW OPERATIONS PREPARATION** |  | 1569.29d? | 2014-01-01 A | 2019-04-08 |  | 74% | 401.74d? | 2016-01-15 | 2018-02-27 | 630.86d | 317.57d |  |  |  | 16222.5h | 13471.8h |
| 255 | 6.1 | **Documentation** |  | 15d | 2017-10-05 A | 2017-10-24 |  | 33% | 10.12d | 2017-10-03 | 2017-10-20 | 15d | 21.43d |  |  |  | 210h | 68.25h |
| 256 | 6.1.1 | OMP issue 1 writing |  | 15d | 2017-10-05 A | 2017-10-24 |  | 45% | 8.25d | 2017-10-03 | 2017-10-20 | 15d | 21.43d |  | start no earlier than 2017-10-05 | X.Bonnin | 105h | 47.25h |
| 257 | 6.1.2 | Bias operations ICD issue 1 writing |  | 15d | 2017-10-05 A | 2017-10-24 |  | 20% | 12d | 2017-10-03 | 2017-10-20 | 15d | 21.43d |  | start no earlier than 2017-10-05 | X.Bonnin | 105h | 21h |

Notes:
- 233: First delivery including source code, preliminary L2S WF-E CDF skeletons and docs. / Main functionalites : / - production of L2S WF-E CDF files from L1 CDF for ROC-SGSE
- 234: including source code + first draft of the user manual + first issue of the SRS / Main functionalities: / - L1R->L2/L2S WF-E data processing
- 235: including source code + first issue of the user manual / Main functionalities: / - L2 WF-E data processing / - ROC ICD fully compliance (interface + descriptor + « automated self-tests »)
- 236: Fully validated version

| ID | WBS | Task | Type | Duration | Start | Finish | Predecessors | Complete | Remaining | Baseline start | Baseline finish | Baseline duration | Total slack | Free slack | Constraint | Resources | Work | Actual work |
| --- | --- | --- | --- | --- | --- | --- | --- | --- | --- | --- | --- | --- | --- | --- | --- | --- | --- | --- |
| 258 | 6.2 | **SVT0** |  | 1383.29d | 2014-01-01 A | 2018-08-22 A |  | 100% |  |  |  |  |  |  |  |  | 11634h | 11620h |
| 259 | 6.2.1 | **SVT0 Datapackage preparation** |  | 1148.86d | 2014-01-01 A | 2017-11-08 A |  | 100% |  | 2016-01-15 | 2017-11-08 | 540.86d |  |  |  |  | 11620h | 11620h |
| 260 | 6.2.1.1 | SVT0 datapackage preparation and pre-validation |  | 800d | 2014-01-01 A | 2016-09-07 A |  | 100% |  |  |  |  |  |  |  | A.Vecchio; Y.de Conchy | 11200h | 11200h |
| 261 | 6.2.1.2 | RPW Instrument State Model (ISM) |  | 30d | 2017-10-03 A | 2017-11-08 A |  | 100% |  | 2017-10-03 | 2017-11-08 | 30d |  |  | start no earlier than 2017-10-03 | A.Vecchio; X.Bonnin | 420h | 420h |
| 262 | 6.2.2 | SVT0 datapackage delivery (ISM is ready but not delivered yet) | milestone | 0d | 2017-09-29 | 2017-09-29 | 260, 261, 367 |  |  | 2017-09-29 | 2017-09-29 | 0d | 0d | 259.43d | finish no later than 2017-09-29 |  |  |  |
| 263 | 6.2.3 | SVT0 validation and report |  | 3d? | 2018-08-17 | 2018-08-21 | 42 |  |  |  |  |  | 552.71d | 0d |  | A.Vecchio [50%] | 10.5h |  |
| 264 | 6.2.4 | Possible SVT0 Datapackage upgrades |  | 1d? | 2018-08-21 | 2018-08-22 | 263 |  |  |  |  |  | 552.71d |  |  | A.Vecchio [50%] | 3.5h |  |
| 265 | 6.3 | **SVT1** |  | 749.57d? | 2016-09-30 A | 2019-04-08 |  |  | 748.21d? | 2017-11-08 | 2018-02-27 | 90d | 0d |  |  |  | 315.22h | 1.03h |
| 266 | 6.3.1 | SVT1 Datapackage preparation |  | 1d | 2016-09-30 A | 2016-10-03 |  | 2% | 0.98d |  |  |  | 0d |  | must start on 2016-09-30 |  | 161.25h | 1.03h |
| 267 | 6.3.2 | Upgraded RPW ISM |  | 4d? | 2017-10-03 | 2017-10-06 |  |  |  | 2017-11-08 | 2017-11-14 | 5d? | 56.57d |  | start no earlier than 2017-10-03 | A.Vecchio [50%]; X.Bonnin; D.Berard | 69.98h |  |
| 268 | 6.3.3 | Upgraded RPW UM |  | 4d? | 2017-10-03 | 2017-10-06 |  |  |  | 2017-11-08 | 2017-11-14 | 5d? | 56.57d |  | start no earlier than 2017-10-03 | A.Vecchio [50%]; CNES support; D.Berard | 69.98h |  |
| 269 | 6.3.4 | SVT1 datapackage delivery | milestone | 0d | 2017-12-15 | 2017-12-15 | 267, 268, 275, 292, 319, 340, 381 |  |  | 2017-12-15 | 2017-12-15 | 0d | 0d | 383.85d | finish no later than 2017-12-15 |  |  |  |
| 270 | 6.3.5 | SVT1 validation and report |  | 1d? | 2019-04-04 | 2019-04-05 | 43 |  |  |  |  |  | 366.71d | 0d |  | D.Berard | 7h |  |
| 271 | 6.3.6 | Possible SVT1 Datapackage upgrades |  | 1d? | 2019-04-05 | 2019-04-08 | 270 |  |  |  |  |  | 366.71d |  |  | D.Berard | 7h |  |
| 272 | 6.4 | **SOV2 (end-to-end CP test)** |  | 43.4d? | 2017-11-08 A | 2018-01-01 |  | 45% | 23.99d? |  |  |  | -12.69d | 0d |  |  | 490h | 215.25h |
| 273 | 6.4.1 | **SOV2 Datapackage preparation** |  | 43.4d? | 2017-11-08 A | 2018-01-01 |  | 46% | 23.29d? | 2017-11-08 | 2017-12-19 | 33d | -12.69d | 0d |  |  | 472.5h | 215.25h |
| 274 | 6.4.1.1 | SOV2 plan and specification (timeline, constraints and organization and validation) |  | 3d? | 2017-11-08 A | 2017-11-10 |  | 50% | 1.5d? |  |  |  | 784.14d |  |  | A.Vecchio [50%] | 10.5h | 5.25h |
| 275 | 6.4.1.2 | Writing flight procedures for SOWG10 LTP exercice concerning CP |  | 40d? | 2017-11-08 A | 2017-12-27 |  | 50% | 20d? | 2017-11-08 | 2017-12-14 | 30d? | -12.69d | 0d | start no earlier than 2017-10-03 | A.Vecchio [50%]; D.Berard | 420h | 210h |
| 276 | 6.4.1.3 | Pre-Validate LTP exercice procedures |  | 1d? | 2017-12-27 | 2017-12-28 | 275 |  |  |  |  |  | -12.69d | 0d |  |  |  |  |
| 277 | 6.4.1.4 | IORs for the SOWG10 LTP excercice |  | 2.4d? | 2017-12-28 | 2018-01-01 | 275, 276 |  |  | 2017-12-14 | 2017-12-19 | 3d? | -12.69d | 0d | start no earlier than 2017-10-03 | A.Vecchio [50%]; X.Bonnin; D.Berard | 42h |  |
| 278 | 6.4.2 | SOV2 datapackage delivery | milestone | 0d | 2017-12-15 | 2017-12-15 | 277 |  |  | 2017-12-15 | 2017-12-15 | 0d | 0d |  | finish no later than 2017-12-15 |  |  |  |
| 279 | 6.4.3 | SOV2 validation and report |  | 0.67d? | 2017-12-15 | 2017-12-15 | 278 |  |  |  |  |  | 754.76d | 0d |  | D.Berard; A.Vecchio [50%] | 7h |  |
| 280 | 6.4.4 | Possible SOV2 Datapackage upgrades |  | 1d? | 2017-12-15 | 2017-12-18 | 279 |  |  |  |  |  | 754.76d |  |  | A.Vecchio [50%]; D.Berard | 10.5h |  |
| 281 | 6.5 | **LEOP-related operations preparation** |  | 71.19d? | 2017-11-08 A | 2018-02-02 |  | 25% | 53.07d? |  |  |  | 27.57d |  |  |  | 684.4h | 636.67h |
| 282 | 6.5.1 | **iBoom deployement** |  | 71.19d? | 2017-11-08 A | 2018-02-02 |  | 26% | 52.95d? |  |  |  | 27.57d |  |  |  | 342.2h | 318.33h |
| 283 | 6.5.1.1 | Operations plan and specification (modes, timeline, constraints and organization and validation) |  | 71.19d? | 2017-11-08 A | 2018-02-02 | 266SS | 26% | 52.44d? |  |  |  | 715.95d |  |  | A.Vecchio [50%]; D.Berard; X.Bonnin; CNES support [1%]; MOC support [1%] | 317.63h | 313.95h |
| 284 | 6.5.1.2 | Procedure writting (only operating modes) |  | 1d? | 2017-11-08 A | 2017-11-09 | 283 | 25% | 0.75d? |  |  |  | 786.14d |  |  | A.Vecchio [50%]; D.Berard | 10.5h | 2.63h |
| 285 | 6.5.1.3 | Procedure pre-validation |  | 1d? | 2017-11-08 A | 2017-11-09 | 284 | 25% | 0.75d? |  |  |  | 27.57d | 0d |  | D.Berard | 7h | 1.75h |
| 286 | 6.5.1.4 | Full sequence pre-validation |  | 1d? | 2017-11-09 | 2017-11-10 | 285 |  |  |  |  |  | 27.57d | 0d |  | D.Berard; LESIA AIT/AIV support [1%] | 7.07h |  |

Notes:
- 260: SVT-0 datapackage / A first set of RPW procedures: / - Switch-On/Off / - Set to science default state (no SBM mode or packet compression) / - Preliminary routine procedures for a nominal STP week (bias sweeping, internal calibration, 10 min. burst mode)
- 262: To be delivered to Sylvain Lodiot (MOC)

| ID | WBS | Task | Duration | Start | Finish | Predecessors | Complete | Remaining | Total slack | Free slack | Resources | Work | Actual work |
| --- | --- | --- | --- | --- | --- | --- | --- | --- | --- | --- | --- | --- | --- |
| 287 | 6.5.2 | **ANT deployment** | 71.19d? | 2017-11-08 A | 2018-02-02 |  | 26% | 52.95d? | 27.57d |  |  | 342.2h | 318.33h |
| 288 | 6.5.2.1 | Operations plan and specification (modes, timeline, constraints and organization and validation) | 71.19d? | 2017-11-08 A | 2018-02-02 | 266SS | 26% | 52.44d? | 715.95d |  | A.Vecchio [50%]; D.Berard; X.Bonnin; CNES support [1%]; MOC support [1%] | 317.63h | 313.95h |
| 289 | 6.5.2.2 | Procedure writting (only operating modes) | 1d? | 2017-11-08 A | 2017-11-09 | 288 | 25% | 0.75d? | 786.14d |  | A.Vecchio [50%]; D.Berard | 10.5h | 2.63h |
| 290 | 6.5.2.3 | Procedure pre-validation | 1d? | 2017-11-08 A | 2017-11-09 | 289 | 25% | 0.75d? | 27.57d | 0d | D.Berard | 7h | 1.75h |
| 291 | 6.5.2.4 | Full sequence pre-validation | 1d? | 2017-11-09 | 2017-11-10 | 290 |  |  | 27.57d | 0d | D.Berard; LESIA AIT/AIV support [1%] | 7.07h |  |
| 292 | 6.5.3 | RPW LEOP operations data package delivery | 1d? | 2017-11-10 | 2017-11-10 | 286, 291 |  |  | 27.57d |  |  |  |  |
| 293 | 6.6 | **NECP-related operations preparation** | 346.25d? | 2016-09-30 A | 2017-11-29 |  |  | 345.83d? | 13.46d |  |  | 1017.77h | 1.03h |
| 294 | 6.6.1 | **Auto-compatibility** | 17.11d? | 2017-11-08 A | 2017-11-29 |  | 1% | 17.01d? | 13.46d |  |  | 261.23h | 1.03h |
| 295 | 6.6.1.1 | Operations plan and specification (modes, timeline, constraints and organization and validation) | 10.11d? | 2017-11-08 A | 2017-11-21 | 266SS | 1% | 10d? | 13.46d | 0d | D.Berard; M.Maksimvovic [40%]; Solo PIs support [1%]; MOC support [1%]; X.Bonnin [85%]; CNES support [1%]; A.Vecchio [50%] | 194.6h | 1.03h |
| 296 | 6.6.1.2 | Procedure writting | 3d? | 2017-11-21 | 2017-11-23 | 295 |  |  | 13.46d | 0d | D.Berard; A.Vecchio [50%] | 31.5h |  |
| 297 | 6.6.1.3 | Procedure pre-validation | 2d? | 2017-11-23 | 2017-11-27 | 296 |  |  | 13.46d | 0d | D.Berard; A.Vecchio [50%] | 21h |  |
| 298 | 6.6.1.4 | Full sequence pre-validation | 2d | 2017-11-27 | 2017-11-29 | 297 |  |  | 13.46d | 0d | D.Berard; LESIA AIT/AIV support [1%] | 14.13h |  |
| 299 | 6.6.2 | **TDS/LFR S/W algo. validation** | 16d? | 2016-09-30 | 2016-10-20 |  |  |  | 343.71d |  |  | 173.03h |  |
| 300 | 6.6.2.1 | Operations plan and specification (modes, timeline, constraints and organization and validation) | 10d? | 2016-09-30 | 2016-10-13 | 266SS |  |  | 343.71d | 0d | D.Berard; LFR support [1%]; TDS support [1%]; X.Bonnin [85%] | 130.9h |  |
| 301 | 6.6.2.2 | Procedure writting | 2d? | 2016-10-13 | 2016-10-14 | 300 |  |  | 343.71d | 0d | D.Berard | 14h |  |
| 302 | 6.6.2.3 | Procedure pre-validation | 2d? | 2016-10-14 | 2016-10-18 | 301 |  |  | 343.71d | 0d | D.Berard | 14h |  |
| 303 | 6.6.2.4 | Full sequence pre-validation | 2d? | 2016-10-18 | 2016-10-20 | 302 |  |  | 343.71d | 330.25d | D.Berard; LESIA AIT/AIV support [1%] | 14.13h |  |
| 304 | 6.6.3 | **RPW-PAS filtering tune** | 16d? | 2016-09-30 | 2016-10-20 |  |  |  | 343.71d |  |  | 173.03h |  |
| 305 | 6.6.3.1 | Operations plan and specification (modes, timeline, constraints and organization and validation) | 10d? | 2016-09-30 | 2016-10-13 | 266SS |  |  | 343.71d | 0d | CNES support [1%]; D.Berard; LFR support [1%]; X.Bonnin [85%] | 130.9h |  |
| 306 | 6.6.3.2 | Procedure writting | 2d? | 2016-10-13 | 2016-10-14 | 305 |  |  | 343.71d | 0d | D.Berard | 14h |  |
| 307 | 6.6.3.3 | Procedure pre-validation | 2d? | 2016-10-14 | 2016-10-18 | 306 |  |  | 343.71d | 0d | D.Berard | 14h |  |
| 308 | 6.6.3.4 | Full sequence pre-validation | 2d? | 2016-10-18 | 2016-10-20 | 307 |  |  | 343.71d | 330.25d | D.Berard; LESIA AIT/AIV support [1%] | 14.13h |  |
| 309 | 6.6.4 | **SBM algo. validation** | 17d? | 2016-09-30 | 2016-10-21 |  |  |  | 342.71d |  |  | 219.93h |  |
| 310 | 6.6.4.1 | Operations plan and specification (modes, timeline, constraints and organization and validation) | 10d? | 2016-09-30 | 2016-10-13 | 266SS |  |  | 342.71d | 0d | D.Berard; DPU software support [1%]; X.Bonnin [85%]; EPD support [1%]; MAG support [1%]; M.Maksimvovic [40%]; SWA support [1%] | 160.3h |  |
| 311 | 6.6.4.2 | Procedure writting | 3d | 2016-10-13 | 2016-10-17 | 310 |  |  | 342.71d | 0d | D.Berard; A.Vecchio [50%] | 31.5h |  |
| 312 | 6.6.4.3 | Procedures pre-validation | 2d? | 2016-10-17 | 2016-10-19 | 311 |  |  | 342.71d | 0d | D.Berard | 14h |  |
| 313 | 6.6.4.4 | Full sequence pre-validation | 2d? | 2016-10-19 | 2016-10-21 | 312 |  |  | 342.71d | 329.25d | D.Berard; LESIA AIT/AIV support [1%] | 14.13h |  |

| ID | WBS | Task | Type | Duration | Start | Finish | Predecessors | Complete | Remaining | Total slack | Free slack | Resources | Work | Actual work |
| --- | --- | --- | --- | --- | --- | --- | --- | --- | --- | --- | --- | --- | --- | --- |
| 314 | 6.6.5 | **HSD SPICE Z-ant bending effect operations** |  | 17d? | 2016-09-30 | 2016-10-21 |  |  |  | 342.71d |  |  | 190.53h |  |
| 315 | 6.6.5.1 | Operations plan and specification (modes, timeline, constraints and organization and validation) |  | 10d? | 2016-09-30 | 2016-10-13 | 266SS |  |  | 342.71d | 0d | CNES support [1%]; D.Berard; SPICE support [1%]; X.Bonnin | 141.4h |  |
| 316 | 6.6.5.2 | Flight procedure writting |  | 3d? | 2016-10-13 | 2016-10-17 | 315 |  |  | 342.71d | 0d | D.Berard | 21h |  |
| 317 | 6.6.5.3 | Flight procedure pre-validation |  | 2d? | 2016-10-17 | 2016-10-19 | 316 |  |  | 342.71d | 0d | D.Berard | 14h |  |
| 318 | 6.6.5.4 | Full sequence pre-validation |  | 2d? | 2016-10-19 | 2016-10-21 | 317 |  |  | 342.71d | 329.25d | D.Berard; LESIA AIT/AIV support [1%] | 14.13h |  |
| 319 | 6.6.6 | RPW NECP operations datapackage delivery | milestone | 0d? | 2017-11-29 | 2017-11-29 | 298, 303, 308, 313, 318 |  |  | 13.46d |  |  |  |  |
| 320 | 6.7 | **CP-related RPW operations preparation** |  | 368.14d? | 2016-09-30 A | 2017-12-26 |  | 51% | 179.12d? | 297.86d |  |  | 1871.1h | 929.6h |
| 321 | 6.7.1 | **CP specific RPW operations (schedule for these operations has to be reported into the ROC E phase planning)** |  | 368.14d? | 2016-09-30 A | 2017-12-26 |  | 1% | 365.84d? | -8.43d | 0d |  | 688.07h | 3.85h |
| 322 | 6.7.1.1 | **ANT CAL roll campaign** |  | 5d? | 2016-09-30 | 2016-10-06 |  |  |  | 353.72d |  |  | 59.48h |  |
| 323 | 6.7.1.1.1 | Operations plan and specification (modes, timeline, constraints and organization and validation) |  | 1d? | 2016-09-30 | 2016-10-03 | 266SS |  |  | 353.72d | 0d | A.Vecchio [50%]; D.Berard; M.Maksimvovic [40%]; THR support [1%]; B.Cecconi [1%]; X.Bonnin [85%] | 31.48h |  |
| 324 | 6.7.1.1.2 | Flight procedure writting |  | 1d? | 2016-10-03 | 2016-10-04 | 323 |  |  | 353.72d | 0d | D.Berard | 7h |  |
| 325 | 6.7.1.1.3 | Flight procedure pre-validation |  | 1d? | 2016-10-04 | 2016-10-04 | 324 |  |  | 353.72d | 0d | D.Berard | 7h |  |
| 326 | 6.7.1.1.4 | IOR writting |  | 1d? | 2016-10-04 | 2016-10-05 | 325 |  |  | 353.72d | 0d | D.Berard | 7h |  |
| 327 | 6.7.1.1.5 | IOR validation |  | 1d? | 2016-10-05 | 2016-10-06 | 326 |  |  | 353.72d | 362.15d | D.Berard | 7h |  |
| 328 | 6.7.1.2 | **SCM noise characterization (Earth-lobe crossing)** |  | 37d? | 2017-11-09 A | 2017-12-25 |  | 1% | 36.7d? | -8.43d | 0d |  | 590.8h | 3.85h |
| 329 | 6.7.1.2.1 | Operations plan and specification (modes, timeline, constraints and organization and validation) |  | 30d? | 2017-11-09 A | 2017-12-15 | 266SS | 1% | 29.76d? | -8.43d | 0d | D.Berard; LFR support [1%]; M.Maksimvovic [40%]; O.Alexandrova [30%]; SCM support [1%]; TDS support [1%]; X.Bonnin [85%] | 541.8h | 3.85h |
| 330 | 6.7.1.2.2 | Flight procedure writting |  | 1d? | 2017-12-15 | 2017-12-18 | 329 |  |  | -8.43d | 0d | D.Berard | 7h |  |
| 331 | 6.7.1.2.3 | Flight procedure pre-validation |  | 4d? | 2017-12-18 | 2017-12-21 | 330 |  |  | -8.43d | 0d | D.Berard | 28h |  |
| 332 | 6.7.1.2.4 | IOR writting |  | 1d? | 2017-12-21 | 2017-12-22 | 331 |  |  | -8.43d | 0d | D.Berard | 7h |  |
| 333 | 6.7.1.2.5 | IOR validation |  | 1d? | 2017-12-22 | 2017-12-25 | 332 |  |  | -8.43d | 0d | D.Berard | 7h |  |
| 334 | 6.7.1.3 | **SBM selective downlink operations life-cycle validation** |  | 5d? | 2016-09-30 | 2016-10-06 |  |  |  | 353.71d |  |  | 37.78h |  |
| 335 | 6.7.1.3.1 | Operations plan and specification (modes, timeline, constraints and organization and validation) |  | 1d? | 2016-09-30 | 2016-10-03 | 266SS |  |  | 353.71d | 0d | A.Vecchio [50%]; D.Berard; EPD support [1%]; MAG support [1%]; RPW flight S/W support [1%]; SOC support [1%]; SWA support [1%]; X.Bonnin [85%] | 16.78h |  |
| 336 | 6.7.1.3.2 | Flight procedure writting |  | 1d? | 2016-10-03 | 2016-10-04 | 335 |  |  | 353.71d | 0d | A.Vecchio [50%]; D.Berard | 10.5h |  |
| 337 | 6.7.1.3.3 | Flight procedure pre-validation |  | 1d? | 2016-10-04 | 2016-10-04 | 336 |  |  | 353.71d | 0d | A.Vecchio [50%]; D.Berard | 10.5h |  |
| 338 | 6.7.1.3.4 | operation request writting (ICD unknown) |  | 1d? | 2016-10-05 | 2016-10-05 | 337 |  |  | 353.71d | 0d |  |  |  |
| 339 | 6.7.1.3.5 | operation request validation |  | 1d? | 2016-10-05 | 2016-10-06 | 338 |  |  | 353.71d | 362.14d |  |  |  |
| 340 | 6.7.1.4 | RPW CP specific operations datapackage |  | 1d? | 2017-12-25 | 2017-12-26 | 327, 333, 339 |  |  | -8.43d | 0d |  |  |  |

| ID | WBS | Task | Type | Duration | Start | Finish | Predecessors | Complete | Constraint | Resources | Work | Actual work |
| --- | --- | --- | --- | --- | --- | --- | --- | --- | --- | --- | --- | --- |
| 341 | 6.7.2 | **Routine operations** |  | 114.29d | 2017-05-30 A | 2017-10-17 A |  | 100% |  |  | 925.87h | 925.75h |
| 342 | 6.7.2.1 | **Bias sweeping** |  | 32.01d | 2017-09-07 A | 2017-10-17 A |  | 100% |  |  | 186.2h | 186.2h |
| 343 | 6.7.2.1.1 | Operations plan and specification (modes, timeline, constraints and organization and validation) |  | 10d | 2017-09-07 A | 2017-09-19 A | 266SS | 100% | start no earlier than 2017-05-01 | A.Vecchio; BIAS support [1%]; M.Maksimvovic [40%]; X.Bonnin [85%] | 158.2h | 158.2h |
| 344 | 6.7.2.1.2 | Flight procedure writting |  | 2d | 2017-10-02 A | 2017-10-04 A | 343 | 100% |  | A.Vecchio | 14h | 14h |
| 345 | 6.7.2.1.3 | Flight procedure pre-validation |  | 2d | 2017-10-13 A | 2017-10-17 A | 344 | 100% |  | A.Vecchio | 14h | 14h |
| 346 | 6.7.2.2 | **Bias calibration** |  | 22.01d | 2017-09-07 A | 2017-10-04 A |  | 100% |  |  | 186.32h | 186.28h |
| 347 | 6.7.2.2.1 | Operations plan and specification (modes, timeline, constraints and organization and validation) |  | 10.01d | 2017-09-07 A | 2017-09-19 A | 266SS | 100% |  | A.Vecchio; BIAS support [1%]; M.Maksimvovic [40%]; X.Bonnin [85%] | 158.32h | 158.28h |
| 348 | 6.7.2.2.2 | Flight procedure writting |  | 2d | 2017-09-19 A | 2017-09-21 A | 347 | 100% |  | A.Vecchio | 14h | 14h |
| 349 | 6.7.2.2.3 | Flight procedure pre-validation |  | 2d | 2017-10-02 A | 2017-10-04 A | 348 | 100% |  | A.Vecchio | 14h | 14h |
| 350 | 6.7.2.3 | **Bias current setting** |  | 13.01d | 2017-09-07 A | 2017-09-22 A |  | 100% |  |  | 193.28h | 193.25h |
| 351 | 6.7.2.3.1 | Operations plan and specification (modes, timeline, constraints and organization and validation) |  | 10.01d | 2017-09-07 A | 2017-09-19 A | 266SS | 100% |  | A.Vecchio; BIAS support [1%]; M.Maksimvovic [40%]; X.Bonnin [85%] | 158.28h | 158.25h |
| 352 | 6.7.2.3.2 | Flight procedure writting |  | 3d | 2017-09-19 A | 2017-09-22 A | 351 | 100% |  | A.Vecchio | 21h | 21h |
| 353 | 6.7.2.3.3 | Flight procedure pre-validation |  | 2d | 2017-09-20 A | 2017-09-22 A | 352 | 100% |  | A.Vecchio | 14h | 14h |
| 354 | 6.7.2.4 | **TDS/LFR SCM cal** |  | 22d | 2017-09-07 A | 2017-10-04 A |  | 100% |  |  | 100.1h | 100.1h |
| 355 | 6.7.2.4.1 | Operations plan and specification (modes, timeline, constraints and organization and validation) |  | 10d | 2017-09-07 A | 2017-09-19 A | 266SS | 100% |  | A.Vecchio; LFR support [1%]; SCM support [1%]; TDS support [1%] | 72.1h | 72.1h |
| 356 | 6.7.2.4.2 | Flight procedure writting |  | 2d | 2017-09-19 A | 2017-09-21 A | 355 | 100% |  | A.Vecchio | 14h | 14h |
| 357 | 6.7.2.4.3 | Flight procedure pre-validation |  | 2d | 2017-10-02 A | 2017-10-04 A | 356 | 100% |  | A.Vecchio | 14h | 14h |
| 358 | 6.7.2.5 | **THR cal** |  | 22d | 2017-09-07 A | 2017-10-04 A |  | 100% |  |  | 112.02h | 112h |
| 359 | 6.7.2.5.1 | Operations plan and specification (modes, timeline, constraints and organization and validation) |  | 10d | 2017-09-07 A | 2017-09-19 A | 266SS | 100% |  | A.Vecchio; M.Maksimvovic [40%] | 98.02h | 98h |
| 360 | 6.7.2.5.2 | Flight procedure writting |  | 2d | 2017-09-19 A | 2017-09-21 A | 359 | 100% |  | A.Vecchio [50%] | 7h | 7h |
| 361 | 6.7.2.5.3 | Flight procedure pre-validation |  | 2d | 2017-10-02 A | 2017-10-04 A | 360 | 100% |  | A.Vecchio [50%] | 7h | 7h |
| 362 | 6.7.2.6 | **Burst mode window** |  | 22d | 2017-09-07 A | 2017-10-04 A |  | 100% |  |  | 126.72h | 126.7h |
| 363 | 6.7.2.6.1 | Operations plan and specification (modes, timeline, constraints and organization and validation) |  | 10.01d | 2017-09-07 A | 2017-09-19 A | 266SS | 100% |  | A.Vecchio; DPU software support [1%]; M.Maksimvovic [40%] | 98.72h | 98.7h |
| 364 | 6.7.2.6.2 | Flight procedure writting |  | 2d | 2017-09-19 A | 2017-09-21 A | 363 | 100% |  | A.Vecchio | 14h | 14h |
| 365 | 6.7.2.6.3 | Flight procedure pre-validation |  | 2d | 2017-10-02 A | 2017-10-04 A | 364 | 100% |  | A.Vecchio | 14h | 14h |
| 366 | 6.7.2.7 | Full procedures sequence pre-validation during deltacal |  | 3d | 2017-05-30 A | 2017-06-01 A | 345, 349, 353, 357, 361, 365 | 100% | start no earlier than 2017-05-30 | A.Vecchio; CNES support [1%] | 21.23h | 21.22h |
| 367 | 6.7.2.8 | RPW CP routine operations datapackage delivery | milestone | 0d | 2017-09-28 A | 2017-09-28 A | 366SS | 100% | start no earlier than 2017-09-28 |  |  |  |

| ID | WBS | Task | Type | Duration | Start | Finish | Predecessors | Complete | Remaining | Baseline start | Baseline finish | Baseline duration | Total slack | Free slack | Resources | Work | Actual work |
| --- | --- | --- | --- | --- | --- | --- | --- | --- | --- | --- | --- | --- | --- | --- | --- | --- | --- |
| 368 | 6.7.3 | **Non-routine operations** |  | 18d? | 2016-09-30 | 2016-10-24 |  |  |  |  |  |  | 341.71d |  |  | 257.17h |  |
| 369 | 6.7.3.1 | **Contingency Recovery** |  | 18d? | 2016-09-30 | 2016-10-24 |  |  |  |  |  |  | 341.71d |  |  | 130.33h |  |
| 370 | 6.7.3.1.1 | Operations plan and specification (modes, timeline, constraints and organization and validation) |  | 10d? | 2016-09-30 | 2016-10-13 | 266SS |  |  |  |  |  | 341.71d | 0d | CNES support [1%]; D.Berard; MEB support [1%]; MOC support [1%]; RPW flight S/W support [1%]; SOC support [1%]; System support [1%] | 74.2h |  |
| 371 | 6.7.3.1.2 | Flight procedure writting |  | 2d? | 2016-10-13 | 2016-10-14 | 370 |  |  |  |  |  | 341.71d | 0d | D.Berard | 14h |  |
| 372 | 6.7.3.1.3 | Flight procedure pre-validation |  | 2d? | 2016-10-14 | 2016-10-18 | 371 |  |  |  |  |  | 341.71d | 0d | D.Berard | 14h |  |
| 373 | 6.7.3.1.4 | PDOR template writting |  | 2d? | 2016-10-18 | 2016-10-20 | 372 |  |  |  |  |  | 341.71d | 0d | D.Berard | 14h |  |
| 374 | 6.7.3.1.5 | Full sequence pre-validation |  | 2d? | 2016-10-20 | 2016-10-24 | 373 |  |  |  |  |  | 341.71d | 0d | D.Berard; LESIA AIT/AIV support [1%] | 14.13h |  |
| 375 | 6.7.3.2 | **Flight software patching** |  | 18d? | 2016-09-30 | 2016-10-24 |  |  |  |  |  |  | 341.71d |  |  | 126.83h |  |
| 376 | 6.7.3.2.1 | Operations plan and specification (modes, timeline, constraints and organization and validation) |  | 10d? | 2016-09-30 | 2016-10-13 | 266SS |  |  |  |  |  | 341.71d | 0d | D.Berard; RPW flight S/W support [1%] | 70.7h |  |
| 377 | 6.7.3.2.2 | Flight procedure writting |  | 2d? | 2016-10-13 | 2016-10-14 | 376 |  |  |  |  |  | 341.71d | 0d | D.Berard | 14h |  |
| 378 | 6.7.3.2.3 | Flight procedure pre-validation |  | 2d? | 2016-10-14 | 2016-10-18 | 377 |  |  |  |  |  | 341.71d | 0d | D.Berard | 14h |  |
| 379 | 6.7.3.2.4 | MDOR template writting |  | 2d? | 2016-10-18 | 2016-10-20 | 378 |  |  |  |  |  | 341.71d | 0d | D.Berard | 14h |  |
| 380 | 6.7.3.2.5 | Full sequence pre-validation |  | 2d? | 2016-10-20 | 2016-10-24 | 379 |  |  |  |  |  | 341.71d | 0d | D.Berard; LESIA AIT/AIV support [1%] | 14.13h |  |
| 381 | 6.7.3.3 | RPW CP non-routine operations datapackage delivery | milestone | 0d | 2016-10-24 | 2016-10-24 | 374, 380 |  |  |  |  |  | 341.71d |  |  |  |  |
| 382 | 7 | **ROC PROJECT MANAGEMENT** |  | 1240.43d? | 2014-01-01 A | 2018-02-28 |  | 63% | 453.43d? | 2014-09-01 | 2026-03-26 | 3450.36d | 695.57d |  |  | 4296.67h | 1612.03h |
| 383 | 7.1 | **High level documentation (requirements and plans)** |  | 916.57d? | 2014-01-01 A | 2017-01-27 |  | 99% | 10.48d? | 2014-09-01 | 2017-01-19 | 712.14d | 1019.43d |  |  | 1311.27h | 1286.63h |
| 384 | 7.1.1 | CIRD issue 1 writing |  | 3d | 2014-09-01 A | 2014-09-03 A |  | 100% |  | 2014-09-01 | 2014-09-03 | 3d |  |  | X.Bonnin [85%] | 17.85h | 17.85h |
| 385 | 7.1.2 | Top level traceability matrix |  | 1.18d | 2014-09-03 A | 2014-09-04 A | 384 | 100% |  |  |  |  |  |  | X.Bonnin [85%] | 7h | 7h |
| 386 | 7.1.3 | PMP issue 1 writing |  | 41.86d | 2015-01-07 A | 2015-02-27 A | 384 | 100% |  | 2017-01-04 | 2017-01-09 | 3d |  |  | X.Bonnin [85%]; Y.de Conchy | 542.05h | 542.05h |
| 387 | 7.1.4 | SPAP issue 1 writing |  | 6.14d | 2016-09-01 A | 2016-09-08 A | 386 | 100% |  | 2017-01-02 | 2017-01-06 | 5d |  |  | S.Papais (NEXEYA) [1%] | 0.43h | 0.43h |
| 388 | 7.1.5 | SDP issue 1 writing |  | 24.43d | 2016-09-01 A | 2016-09-30 A | 387SS | 100% |  | 2017-01-06 | 2017-01-12 | 5d |  |  | X.Bonnin [85%] | 145.35h | 145.35h |
| 389 | 7.1.6 | SVP issue 1 writing |  | 1d | 2016-09-30 A | 2016-10-03 A | 388 | 100% |  |  |  |  |  |  | S.Lion | 7h | 7h |
| 390 | 7.1.7 | Planning ROC issue 1 writing |  | 95.29d | 2016-10-03 A | 2017-01-27 A | 384, 386, 387, 388SS | 100% |  | 2017-01-12 | 2017-01-19 | 5d |  |  | X.Bonnin [85%] | 566.95h | 566.95h |
| 391 | 7.1.8 | CIRD-RSSS traceability matrix |  | 1d? | 2014-01-01 | 2014-01-01 |  |  |  |  |  |  | 1935d |  | S.Lion; S.Papais (NEXEYA) [1%]; X.Bonnin [75%] | 12.32h |  |
| 392 | 7.1.9 | RSSS-RSDD traceability matrix |  | 1d? | 2014-01-01 | 2014-01-01 |  |  |  |  |  |  | 1935d |  | S.Lion; S.Papais (NEXEYA) [1%]; X.Bonnin [75%] | 12.32h |  |

| ID | WBS | Task | Duration | Start | Finish | Predecessors | Complete | Remaining | Baseline start | Baseline finish | Baseline duration | Total slack | Constraint | Resources | Work | Actual work |
| --- | --- | --- | --- | --- | --- | --- | --- | --- | --- | --- | --- | --- | --- | --- | --- | --- |
| 393 | 7.2 | **Guidelines** | 60d | 2015-09-01 A | 2015-11-12 A |  | 100% |  | 2017-01-19 | 2017-01-24 | 4d |  |  |  | 289h | 289h |
| 394 | 7.2.1 | REG issue 1 writing | 26d | 2015-09-01 A | 2015-10-01 A | 388 | 100% |  | 2017-01-19 | 2017-01-20 | 2d |  |  | X.Bonnin [85%] | 154.7h | 154.7h |
| 395 | 7.2.2 | REGU issue 1 writing | 22.57d | 2015-10-15 A | 2015-11-12 A | 394 | 100% |  | 2017-01-20 | 2017-01-24 | 2d |  |  | X.Bonnin [85%] | 134.3h | 134.3h |
| 396 | 7.3 | **User manuals** | 144.85d? | 2017-09-04 A | 2018-02-28 |  | 15% | 122.91d? | 2026-02-09 | 2026-03-26 | 37.5d | 42d |  |  | 2696.4h | 36.4h |
| 397 | 7.3.1 | ROC UM issue 1 writing | 60d | 2017-12-18 | 2018-02-28 | 150 |  |  | 2026-02-09 | 2026-03-26 | 37.5d | 174.29d |  | A.Aboubacar; S.Lion; X.Bonnin [85%] | 1197h |  |
| 398 | 7.3.2 | ROC RG issue 1 writing | 60d | 2017-12-18 | 2018-02-28 | 150 |  |  | 2026-02-09 | 2026-03-26 | 37.5d | 174.29d |  | A.Aboubacar; S.Lion; X.Bonnin [85%] | 1197h |  |
| 399 | 7.3.3 | RPW LLVM UM issue 1 writing | 5d | 2017-10-16 A | 2017-10-20 A | 37 | 100% |  | 2026-02-09 | 2026-02-13 | 5d |  |  | S.Lion | 35h | 35h |
| 400 | 7.3.4 | ROC SRF issue 1 writing | 20d | 2017-09-04 A | 2017-09-28 A |  | 100% |  | 2026-02-09 | 2026-02-19 | 10d? |  | start no earlier than 2017-09-04 | S.Papais (NEXEYA) [1%] | 1.4h | 1.4h |
| 401 | 7.3.5 | ROC SCF issue 1 writing | 20d? | 2017-10-05 | 2017-10-31 |  |  |  | 2026-02-09 | 2026-02-10 | 1d? | 15.71d | start no earlier than 2017-10-05 | S.Lion; X.Bonnin [85%]; S.Papais (NEXEYA) [5%] | 266h |  |
